# Learning Management System Implementation

Schedule from MS Project, 2016-04-12 to 2017-04-28.
*********Copyright Info********* / * Lifetime access 50% discount for just $12 - 100+ video Lessons, Quizzes, 100+ exercise files: / * https://www.udemy.com/microsoft-project-tutorial/?couponCode=copyrightDiscount / * CONQUER Microsoft Project 2016 today! Get promotions, respect of peers and mastery of your domain. / * Approved for 10 FREE PMP PDU points from Project Management Institute PMI©. / * Copyright Srikanth R Shirodkar 2016-2020. email: srikanth.shirodkar@gmail.com / ********************************

## Calendars

- Standard: Mon-Fri 08:00-12:00, 13:00-17:00; Sat-Sun off.

## Resources

| Resource |
| --- |
| PM |
| Vendor |
| Content Vendor |
| Test Lead |
| Mobile Vendor |
| UX Team |
| Web Design Vendor |
| Deploy Team |
| Maintenance Vendor |
| Technical Writer |
| IT Director |
| PMO |
| CEO |
| CFO |
| Approval Board |
| IT Manager |
| Faculty Rep |
| Dean |
| faculty |
| Develop Team |
| Testing Team |
| Architect |
| Content Team |
| Stakeholders |

## Schedule

| ID | WBS | Task | Type | Duration | Start | Finish | Predecessors | Total slack | Constraint | Resources | Work |
| --- | --- | --- | --- | --- | --- | --- | --- | --- | --- | --- | --- |
| 1 | 1 | **Planning Phase** |  | 35d | 2016-04-12 | 2016-05-30 |  | 0d |  |  | 280h |
| 2 | 1.1 | Strategic Objectives |  | 7d | 2016-04-12 | 2016-04-20 |  | 0d |  | PMO | 56h |
| 3 | 1.2 | Budgetary Objectives |  | 5d | 2016-04-21 | 2016-04-27 | 2 | 0d |  | PMO | 40h |
| 4 | 1.3 | Compliance and Regulatory requirements |  | 6d | 2016-04-28 | 2016-05-05 | 3 | 0d |  | PMO | 48h |
| 5 | 1.4 | Partners/Suppliers/Corporate Objectives |  | 2d | 2016-05-06 | 2016-05-09 | 4 | 0d |  | PMO | 16h |
| 6 | 1.5 | Doc: Strategic Objectives document |  | 7d | 2016-05-10 | 2016-05-18 | 5 | 0d |  | PM | 56h |
| 7 | 1.6 | Review Objectives Document |  | 5d | 2016-05-19 | 2016-05-25 | 6 | 0d |  | Approval Board | 40h |
| 8 | 1.7 | Signoff Objectives |  | 3d | 2016-05-26 | 2016-05-30 | 7 | 0d |  | Approval Board | 24h |
| 9 | 1.8 | Milestone: Planning Complete | milestone | 0d | 2016-05-30 | 2016-05-30 | 8 | 0d |  |  |  |
| 10 | 2 | **Weekly Review Meeting** |  | 195.25d | 2016-06-06 | 2017-03-06 |  | 39.75d |  | Stakeholders | 1562h |
| 11 | 2.1 | Weekly Review Meeting 1 |  | 2h | 2016-06-06 | 2016-06-06 |  | 234.75d | start no earlier than 2016-06-06 |  |  |
| 12 | 2.2 | Weekly Review Meeting 2 |  | 2h | 2016-06-13 | 2016-06-13 |  | 229.75d | start no earlier than 2016-06-13 |  |  |
| 13 | 2.3 | Weekly Review Meeting 3 |  | 2h | 2016-06-20 | 2016-06-20 |  | 224.75d | start no earlier than 2016-06-20 |  |  |
| 14 | 2.4 | Weekly Review Meeting 4 |  | 2h | 2016-06-27 | 2016-06-27 |  | 219.75d | start no earlier than 2016-06-27 |  |  |
| 15 | 2.5 | Weekly Review Meeting 5 |  | 2h | 2016-07-04 | 2016-07-04 |  | 214.75d | start no earlier than 2016-07-04 |  |  |
| 16 | 2.6 | Weekly Review Meeting 6 |  | 2h | 2016-07-11 | 2016-07-11 |  | 209.75d | start no earlier than 2016-07-11 |  |  |
| 17 | 2.7 | Weekly Review Meeting 7 |  | 2h | 2016-07-18 | 2016-07-18 |  | 204.75d | start no earlier than 2016-07-18 |  |  |
| 18 | 2.8 | Weekly Review Meeting 8 |  | 2h | 2016-07-25 | 2016-07-25 |  | 199.75d | start no earlier than 2016-07-25 |  |  |
| 19 | 2.9 | Weekly Review Meeting 9 |  | 2h | 2016-08-01 | 2016-08-01 |  | 194.75d | start no earlier than 2016-08-01 |  |  |
| 20 | 2.10 | Weekly Review Meeting 10 |  | 2h | 2016-08-08 | 2016-08-08 |  | 189.75d | start no earlier than 2016-08-08 |  |  |
| 21 | 2.11 | Weekly Review Meeting 11 |  | 2h | 2016-08-15 | 2016-08-15 |  | 184.75d | start no earlier than 2016-08-15 |  |  |
| 22 | 2.12 | Weekly Review Meeting 12 |  | 2h | 2016-08-22 | 2016-08-22 |  | 179.75d | start no earlier than 2016-08-22 |  |  |
| 23 | 2.13 | Weekly Review Meeting 13 |  | 2h | 2016-08-29 | 2016-08-29 |  | 174.75d | start no earlier than 2016-08-29 |  |  |
| 24 | 2.14 | Weekly Review Meeting 14 |  | 2h | 2016-09-05 | 2016-09-05 |  | 169.75d | start no earlier than 2016-09-05 |  |  |
| 25 | 2.15 | Weekly Review Meeting 15 |  | 2h | 2016-09-12 | 2016-09-12 |  | 164.75d | start no earlier than 2016-09-12 |  |  |
| 26 | 2.16 | Weekly Review Meeting 16 |  | 2h | 2016-09-19 | 2016-09-19 |  | 159.75d | start no earlier than 2016-09-19 |  |  |
| 27 | 2.17 | Weekly Review Meeting 17 |  | 2h | 2016-09-26 | 2016-09-26 |  | 154.75d | start no earlier than 2016-09-26 |  |  |
| 28 | 2.18 | Weekly Review Meeting 18 |  | 2h | 2016-10-03 | 2016-10-03 |  | 149.75d | start no earlier than 2016-10-03 |  |  |
| 29 | 2.19 | Weekly Review Meeting 19 |  | 2h | 2016-10-10 | 2016-10-10 |  | 144.75d | start no earlier than 2016-10-10 |  |  |
| 30 | 2.20 | Weekly Review Meeting 20 |  | 2h | 2016-10-17 | 2016-10-17 |  | 139.75d | start no earlier than 2016-10-17 |  |  |
| 31 | 2.21 | Weekly Review Meeting 21 |  | 2h | 2016-10-24 | 2016-10-24 |  | 134.75d | start no earlier than 2016-10-24 |  |  |
| 32 | 2.22 | Weekly Review Meeting 22 |  | 2h | 2016-10-31 | 2016-10-31 |  | 129.75d | start no earlier than 2016-10-31 |  |  |
| 33 | 2.23 | Weekly Review Meeting 23 |  | 2h | 2016-11-07 | 2016-11-07 |  | 124.75d | start no earlier than 2016-11-07 |  |  |
| 34 | 2.24 | Weekly Review Meeting 24 |  | 2h | 2016-11-14 | 2016-11-14 |  | 119.75d | start no earlier than 2016-11-14 |  |  |
| 35 | 2.25 | Weekly Review Meeting 25 |  | 2h | 2016-11-21 | 2016-11-21 |  | 114.75d | start no earlier than 2016-11-21 |  |  |
| 36 | 2.26 | Weekly Review Meeting 26 |  | 2h | 2016-11-28 | 2016-11-28 |  | 109.75d | start no earlier than 2016-11-28 |  |  |
| 37 | 2.27 | Weekly Review Meeting 27 |  | 2h | 2016-12-05 | 2016-12-05 |  | 104.75d | start no earlier than 2016-12-05 |  |  |
| 38 | 2.28 | Weekly Review Meeting 28 |  | 2h | 2016-12-12 | 2016-12-12 |  | 99.75d | start no earlier than 2016-12-12 |  |  |
| 39 | 2.29 | Weekly Review Meeting 29 |  | 2h | 2016-12-19 | 2016-12-19 |  | 94.75d | start no earlier than 2016-12-19 |  |  |
| 40 | 2.30 | Weekly Review Meeting 30 |  | 2h | 2016-12-26 | 2016-12-26 |  | 89.75d | start no earlier than 2016-12-26 |  |  |
| 41 | 2.31 | Weekly Review Meeting 31 |  | 2h | 2017-01-02 | 2017-01-02 |  | 84.75d | start no earlier than 2017-01-02 |  |  |
| 42 | 2.32 | Weekly Review Meeting 32 |  | 2h | 2017-01-09 | 2017-01-09 |  | 79.75d | start no earlier than 2017-01-09 |  |  |
| 43 | 2.33 | Weekly Review Meeting 33 |  | 2h | 2017-01-16 | 2017-01-16 |  | 74.75d | start no earlier than 2017-01-16 |  |  |
| 44 | 2.34 | Weekly Review Meeting 34 |  | 2h | 2017-01-23 | 2017-01-23 |  | 69.75d | start no earlier than 2017-01-23 |  |  |
| 45 | 2.35 | Weekly Review Meeting 35 |  | 2h | 2017-01-30 | 2017-01-30 |  | 64.75d | start no earlier than 2017-01-30 |  |  |
| 46 | 2.36 | Weekly Review Meeting 36 |  | 2h | 2017-02-06 | 2017-02-06 |  | 59.75d | start no earlier than 2017-02-06 |  |  |
| 47 | 2.37 | Weekly Review Meeting 37 |  | 2h | 2017-02-13 | 2017-02-13 |  | 54.75d | start no earlier than 2017-02-13 |  |  |
| 48 | 2.38 | Weekly Review Meeting 38 |  | 2h | 2017-02-20 | 2017-02-20 |  | 49.75d | start no earlier than 2017-02-20 |  |  |
| 49 | 2.39 | Weekly Review Meeting 39 |  | 2h | 2017-02-27 | 2017-02-27 |  | 44.75d | start no earlier than 2017-02-27 |  |  |
| 50 | 2.40 | Weekly Review Meeting 40 |  | 2h | 2017-03-06 | 2017-03-06 |  | 39.75d | start no earlier than 2017-03-06 |  |  |

| ID | WBS | Task | Type | Duration | Start | Finish | Predecessors | Total slack | Free slack | Resources | Work |
| --- | --- | --- | --- | --- | --- | --- | --- | --- | --- | --- | --- |
| 51 | 3 | **Detailed Design Phase** |  | 73d | 2016-05-31 | 2016-09-08 |  | 0d |  |  | 824h |
| 52 | 3.1 | Technology Considerations |  | 3d | 2016-05-31 | 2016-06-02 | 9 | 0d |  | IT Manager | 24h |
| 53 | 3.2 | Integration Considerations |  | 6d | 2016-06-03 | 2016-06-10 | 52 | 0d |  | IT Manager | 48h |
| 54 | 3.3 | Non Functional Requirements |  | 6d | 2016-06-13 | 2016-06-20 | 53 | 0d |  | IT Director | 48h |
| 55 | 3.4 | Administrative Needs and Roles |  | 4d | 2016-06-21 | 2016-06-24 | 54 | 0d |  | IT Manager | 32h |
| 56 | 3.5 | RACI Matrix for LMS - Org wide |  | 6d | 2016-06-27 | 2016-07-04 | 55 | 0d |  | PMO | 48h |
| 57 | 3.6 | Content Strategy |  | 2w | 2016-07-05 | 2016-07-18 | 56 | 0d |  | IT Manager; Faculty Rep; Dean | 240h |
| 58 | 3.7 | Marketing Requirements |  | 1w | 2016-07-19 | 2016-07-25 | 57 | 0d |  | PMO | 40h |
| 59 | 3.8 | Deployment Plan (rollout to all colleges) |  | 1w | 2016-07-26 | 2016-08-01 | 58 | 0d |  | IT Manager | 40h |
| 60 | 3.9 | Doc: Functional Specification Document (FSD) |  | 1w | 2016-08-02 | 2016-08-08 | 59 | 0d |  | Technical Writer | 40h |
| 61 | 3.10 | Review: FSD |  | 2d | 2016-08-09 | 2016-08-10 | 60 | 0d |  | IT Director | 16h |
| 62 | 3.11 | Signoff: FSD |  | 2d | 2016-08-11 | 2016-08-12 | 61 | 0d |  | IT Director | 16h |
| 63 | 3.12 | Doc: Technical Specifications Document (TSD) |  | 5d | 2016-08-15 | 2016-08-19 | 62 | 0d |  | IT Manager | 40h |
| 64 | 3.13 | Review: TSD |  | 2d | 2016-08-22 | 2016-08-23 | 63 | 0d |  | IT Director | 16h |
| 65 | 3.14 | Signoff: TSD |  | 2d | 2016-08-24 | 2016-08-25 | 64 | 0d |  | IT Director | 16h |
| 66 | 3.15 | Content Strategy Document (CSD) |  | 2w | 2016-08-26 | 2016-09-08 | 65 | 0d |  | Faculty Rep; IT Manager | 160h |
| 67 | 3.16 | Milestone: Detailed Design Complete | milestone | 0d | 2016-09-08 | 2016-09-08 | 66 | 0d |  |  |  |
| 68 | 4 | **Implementation Phase** |  | 90d | 2016-09-09 | 2017-01-12 |  | 0d |  |  | 2320h |
| 69 | 4.1 | Testing Server Setup |  | 2d | 2016-09-09 | 2016-09-12 | 67 | 95d | 0d | Deploy Team | 16h |
| 70 | 4.2 | Development Server Setup |  | 2d | 2016-09-13 | 2016-09-14 | 69 | 95d | 0d | Deploy Team | 16h |
| 71 | 4.3 | Install: Moodle Test installation |  | 1d | 2016-09-15 | 2016-09-15 | 70 | 95d | 0d | Deploy Team | 8h |
| 72 | 4.4 | Database design |  | 5d | 2016-09-16 | 2016-09-22 | 71 | 95d | 0d | Architect | 40h |
| 73 | 4.5 | Doc: Upgrade Strategy Document (USD) |  | 5d | 2016-09-23 | 2016-09-29 | 72 | 95d | 0d | Architect | 40h |
| 74 | 4.6 | **Moodle: LMS Structure** |  | 20d | 2016-09-30 | 2016-10-27 |  | 95d |  |  | 160h |
| 75 | 4.6.1 | Home Page |  | 3d | 2016-09-30 | 2016-10-04 | 73 | 95d | 0d | Develop Team | 24h |
| 76 | 4.6.2 | Main Landing Page |  | 8d | 2016-10-05 | 2016-10-14 | 75 | 95d | 0d | Develop Team | 64h |
| 77 | 4.6.3 | Institution Landing Pages |  | 5d | 2016-10-17 | 2016-10-21 | 76 | 95d | 0d | Develop Team | 40h |
| 78 | 4.6.4 | Course Landing Pages |  | 4d | 2016-10-24 | 2016-10-27 | 77 | 95d | 0d | Develop Team | 32h |

| ID | WBS | Task | Type | Duration | Start | Finish | Predecessors | Total slack | Free slack | Resources | Work |
| --- | --- | --- | --- | --- | --- | --- | --- | --- | --- | --- | --- |
| 79 | 4.7 | **Moodle: Course Design and Planning** |  | 12d | 2016-10-28 | 2016-11-14 |  | 95d |  |  | 96h |
| 80 | 4.7.1 | Courses Upload |  | 5d | 2016-10-28 | 2016-11-03 | 78 | 95d | 0d | Content Team | 40h |
| 81 | 4.7.2 | Courses Structuring |  | 4d | 2016-11-04 | 2016-11-09 | 80 | 95d | 0d | Content Team | 32h |
| 82 | 4.7.3 | Courses Support Material Upload |  | 3d | 2016-11-10 | 2016-11-14 | 81 | 95d | 0d | Content Team | 24h |
| 83 | 4.8 | **Moodle: Course Creation** |  | 12d | 2016-11-15 | 2016-11-30 |  | 95d |  |  | 96h |
| 84 | 4.8.1 | Course Space Creation |  | 5d | 2016-11-15 | 2016-11-21 | 82 | 95d | 0d | Content Team | 40h |
| 85 | 4.8.2 | Course Pages |  | 4d | 2016-11-22 | 2016-11-25 | 84 | 95d | 0d | Content Team | 32h |
| 86 | 4.8.3 | Assessment Requirements |  | 3d | 2016-11-28 | 2016-11-30 | 85 | 95d | 0d | Faculty Rep | 24h |
| 87 | 4.9 | **Moodle: Performance and Control Considerations** |  | 12d | 2016-12-01 | 2016-12-16 |  | 95d |  |  | 96h |
| 88 | 4.9.1 | Automated and Manual Communications setup |  | 5d | 2016-12-01 | 2016-12-07 | 86 | 95d | 0d | Architect | 40h |
| 89 | 4.9.2 | Support Pages Configuration |  | 4d | 2016-12-08 | 2016-12-13 | 88 | 95d | 0d | Faculty Rep | 32h |
| 90 | 4.9.3 | Course Release Strategy |  | 3d | 2016-12-14 | 2016-12-16 | 89 | 95d |  | Content Team | 24h |
| 91 | 4.10 | **LMS User Experience** |  | 34d | 2016-09-09 | 2016-10-26 |  | 56d |  |  | 272h |
| 92 | 4.10.1 | Doc: UX Design document (UXD) |  | 5d | 2016-09-09 | 2016-09-15 | 67 | 56d | 0d | Web Design Vendor | 40h |
| 93 | 4.10.2 | Review: UXD |  | 2d | 2016-09-16 | 2016-09-19 | 92 | 56d | 0d | Web Design Vendor | 16h |
| 94 | 4.10.3 | Signoff: UXD |  | 2d | 2016-09-20 | 2016-09-21 | 93 | 56d | 0d | Web Design Vendor | 16h |
| 95 | 4.10.4 | Custom Theme Development |  | 2w | 2016-09-22 | 2016-10-05 | 94 | 56d | 0d | Web Design Vendor | 80h |
| 96 | 4.10.5 | Department-wide custom themes |  | 1w | 2016-10-06 | 2016-10-12 | 95 | 56d | 0d | Web Design Vendor | 40h |
| 97 | 4.10.6 | Logo and Branding requirements |  | 5d | 2016-10-13 | 2016-10-19 | 96 | 56d | 0d | Web Design Vendor | 40h |
| 98 | 4.10.7 | Marketing UX reqts |  | 5d | 2016-10-20 | 2016-10-26 | 97 | 56d | 0d | Web Design Vendor | 40h |
| 99 | 4.10.8 | Milestone: UX complete | milestone | 0d | 2016-10-26 | 2016-10-26 | 98 | 56d |  | Web Design Vendor |  |
| 100 | 4.11 | **LMS Content Migration** |  | 90d | 2016-09-09 | 2017-01-12 |  | 0d |  |  | 720h |
| 101 | 4.11.1 | Content Vendor Selection |  | 5d | 2016-09-09 | 2016-09-15 | 67 | 0d |  | PM | 40h |
| 102 | 4.11.2 | Content Vendor Engage |  | 5d | 2016-09-16 | 2016-09-22 | 101 | 0d |  | PM | 40h |
| 103 | 4.11.3 | Migrate SCORM Content |  | 10d | 2016-09-23 | 2016-10-06 | 102 | 0d |  | Content Vendor | 80h |
| 104 | 4.11.4 | Vendonr: New Content Creation |  | 60d | 2016-10-07 | 2016-12-29 | 103 | 0d |  | Content Vendor | 480h |
| 105 | 4.11.5 | Vendor: New content Upload |  | 10d | 2016-12-30 | 2017-01-12 | 104 | 0d |  | Content Vendor | 80h |
| 106 | 4.11.6 | Milestone: Migration done | milestone | 0d | 2017-01-12 | 2017-01-12 | 105 | 0d |  | Content Vendor |  |

| ID | WBS | Task | Type | Duration | Start | Finish | Predecessors | Total slack | Free slack | Resources | Work |
| --- | --- | --- | --- | --- | --- | --- | --- | --- | --- | --- | --- |
| 107 | 4.12 | **Mobile App Development** |  | 60d | 2016-09-30 | 2016-12-22 |  | 15d |  |  | 480h |
| 108 | 4.12.1 | Mobile Dev Vendor Selection |  | 1w | 2016-09-30 | 2016-10-06 | 67FS+15d | 15d | 0d | PM | 40h |
| 109 | 4.12.2 | Requirements and signoff |  | 2w | 2016-10-07 | 2016-10-20 | 108 | 15d | 0d | Mobile Vendor | 80h |
| 110 | 4.12.3 | Notifications |  | 4d | 2016-10-21 | 2016-10-26 | 109 | 15d | 0d | Mobile Vendor | 32h |
| 111 | 4.12.4 | Calendar |  | 2d | 2016-10-27 | 2016-10-28 | 110 | 15d | 0d | Mobile Vendor | 16h |
| 112 | 4.12.5 | Quiz Engine |  | 15d | 2016-10-31 | 2016-11-18 | 111 | 15d | 0d | Mobile Vendor | 120h |
| 113 | 4.12.6 | Annual Time Table |  | 2d | 2016-11-21 | 2016-11-22 | 112 | 15d | 0d | Mobile Vendor | 16h |
| 114 | 4.12.7 | Messaging |  | 1w | 2016-11-23 | 2016-11-29 | 113 | 15d | 0d | Mobile Vendor | 40h |
| 115 | 4.12.8 | Social Integration |  | 2d | 2016-11-30 | 2016-12-01 | 114 | 15d | 0d | Mobile Vendor | 16h |
| 116 | 4.12.9 | Usability Testing |  | 5d | 2016-12-02 | 2016-12-08 | 115 | 15d | 0d | Mobile Vendor | 40h |
| 117 | 4.12.10 | Functional Testing |  | 5d | 2016-12-09 | 2016-12-15 | 116 | 15d | 0d | Mobile Vendor | 40h |
| 118 | 4.12.11 | Integration testing |  | 5d | 2016-12-16 | 2016-12-22 | 117 | 15d | 0d | Mobile Vendor | 40h |
| 119 | 4.12.12 | Milestone: Mobile dev complete | milestone | 0d | 2016-12-22 | 2016-12-22 | 118 | 15d |  | Mobile Vendor |  |
| 120 | 4.13 | **Testing Plan and Setup** |  | 35d | 2016-10-21 | 2016-12-08 |  | 25d |  |  | 280h |
| 121 | 4.13.1 | Doc: Test Specification Document (TSD) |  | 2w | 2016-10-21 | 2016-11-03 | 67FS+30d | 25d | 0d | Test Lead | 80h |
| 122 | 4.13.2 | Test team setup |  | 5d | 2016-11-04 | 2016-11-10 | 121 | 25d | 0d | Test Lead | 40h |
| 123 | 4.13.3 | Review: TSD |  | 3d | 2016-11-11 | 2016-11-15 | 122 | 25d | 0d | Test Lead | 24h |
| 124 | 4.13.4 | Signoff: TSD |  | 2d | 2016-11-16 | 2016-11-17 | 123 | 25d | 0d | Test Lead | 16h |
| 125 | 4.13.5 | Content Test Strategy |  | 2w | 2016-11-18 | 2016-12-01 | 124 | 25d | 0d | Test Lead | 80h |
| 126 | 4.13.6 | Usability Test Strategy |  | 1w | 2016-12-02 | 2016-12-08 | 125 | 25d |  | Test Lead | 40h |
| 127 | 4.14 | Milestone: Implementation Complete | milestone | 0d | 2017-01-12 | 2017-01-12 | 126, 106, 119, 99 | 0d |  |  |  |
| 128 | 5 | **Integration Phase** |  | 54d | 2017-01-13 | 2017-03-29 |  | 0d |  |  | 432h |
| 129 | 5.1 | Single Sign On (SSO) Setup |  | 3d | 2017-01-13 | 2017-01-17 | 127 | 0d |  | Deploy Team | 24h |
| 130 | 5.2 | Student Information System (SIS) Setup |  | 5d | 2017-01-18 | 2017-01-24 | 129 | 1d | 0d | Deploy Team | 40h |
| 131 | 5.3 | Datewarehousing Integration (Learning Analytics) |  | 10d | 2017-01-25 | 2017-02-07 | 130 | 1d | 0d | Deploy Team | 80h |
| 132 | 5.4 | SAP Integration |  | 15d | 2017-02-08 | 2017-02-28 | 131 | 1d | 0d | Deploy Team | 120h |
| 133 | 5.5 | Accounting Software Setup |  | 5d | 2017-03-01 | 2017-03-07 | 132 | 1d | 0d | Deploy Team | 40h |

Notes:
- 121: Start writing the Test Plan after the detailed design is complete - and implementation has started
- 127: Note the multiple dependencies for this milestone to complete

| ID | WBS | Task | Type | Duration | Start | Finish | Predecessors | Total slack | Free slack | Resources | Work |
| --- | --- | --- | --- | --- | --- | --- | --- | --- | --- | --- | --- |
| 134 | 5.6 | **STAGING SERVER SETUP** |  | 16d | 2017-03-08 | 2017-03-29 |  | 1d |  |  | 128h |
| 135 | 5.6.1 | Server setup, Redundancy setup |  | 3d | 2017-03-08 | 2017-03-10 | 133 | 1d | 0d | Deploy Team | 24h |
| 136 | 5.6.2 | Database Configuration |  | 3d | 2017-03-13 | 2017-03-15 | 135 | 1d | 0d | Deploy Team | 24h |
| 137 | 5.6.3 | LMS Installation |  | 2d | 2017-03-16 | 2017-03-17 | 136 | 1d | 0d | Deploy Team | 16h |
| 138 | 5.6.4 | Course Data Migration |  | 3d | 2017-03-20 | 2017-03-22 | 137 | 1d | 0d | Deploy Team | 24h |
| 139 | 5.6.5 | Student Data Import |  | 3d | 2017-03-23 | 2017-03-27 | 138 | 1d | 0d | Deploy Team | 24h |
| 140 | 5.6.6 | RBAC Setup and testing |  | 2d | 2017-03-28 | 2017-03-29 | 139 | 1d | 0d | Deploy Team | 16h |
| 141 | 5.6.7 | Milestone: Integration Phase Complete | milestone | 0d | 2017-03-29 | 2017-03-29 | 140 | 1d | 0d |  |  |
| 142 | 6 | **VERIFICATION and STAGING** |  | 125d | 2016-10-28 | 2017-04-20 |  | 6d |  |  | 1080h |
| 143 | 6.1 | Unit Testing of all modules |  | 2mo | 2016-10-28 | 2016-12-22 | 68SS+2.5% | 6d | 0d | Develop Team | 320h |
| 144 | 6.2 | Functional Testing |  | 3w | 2016-12-23 | 2017-01-12 | 143 | 6d | 0d | Testing Team | 120h |
| 145 | 6.3 | Installation and Deploy Testing |  | 2w | 2017-01-13 | 2017-01-26 | 144 | 6d | 0d | Testing Team | 80h |
| 146 | 6.4 | Performance Testing |  | 2w | 2017-01-27 | 2017-02-09 | 145 | 6d | 0d | Testing Team | 80h |
| 147 | 6.5 | Usability Testing |  | 2w | 2017-02-10 | 2017-02-23 | 146 | 6d | 0d | Testing Team | 80h |
| 148 | 6.6 | Alpha Testing |  | 2w | 2017-02-24 | 2017-03-09 | 147 | 6d | 0d | Testing Team | 80h |
| 149 | 6.7 | UAT Scripting |  | 2w | 2017-03-10 | 2017-03-23 | 148 | 6d | 0d | Testing Team | 80h |
| 150 | 6.8 | UAT cases review and approval |  | 2w | 2017-03-24 | 2017-04-06 | 149 | 6d | 0d | Testing Team | 80h |
| 151 | 6.9 | User Acceptance Testing |  | 2w | 2017-04-07 | 2017-04-20 | 150 | 6d | 0d | Testing Team; Faculty Rep | 160h |
| 152 | 6.10 | Milestone: Testing Complete | milestone | 0d | 2017-04-20 | 2017-04-20 | 151 | 6d |  |  |  |
| 153 | 7 | **PRODUCTION DEPLOYMENT** |  | 21d | 2017-03-30 | 2017-04-27 |  | 1d |  |  | 168h |
| 154 | 7.1 | Hardware, Software, Database Setup, Configuration |  | 5d | 2017-03-30 | 2017-04-05 | 141 | 1d | 0d | Deploy Team | 40h |
| 155 | 7.2 | Course Data Migration |  | 6d | 2017-04-06 | 2017-04-13 | 154 | 1d | 0d | Deploy Team | 48h |
| 156 | 7.3 | Student Data Migration |  | 4d | 2017-04-14 | 2017-04-19 | 155 | 1d | 0d | Deploy Team | 32h |
| 157 | 7.4 | Course Creation - all Colleges |  | 5d | 2017-04-20 | 2017-04-26 | 156 | 1d | 0d | Deploy Team | 40h |
| 158 | 7.5 | Roles and Accounts |  | 1d | 2017-04-27 | 2017-04-27 | 157 | 1d | 0d | Deploy Team | 8h |
| 159 | 7.6 | Milestone: Prod Deploy Complete | milestone | 0d | 2017-04-27 | 2017-04-27 | 158 | 1d |  |  |  |

Notes:
- 144: Testing can start when Implementation has completed atleast 25%

| ID | WBS | Task | Type | Duration | Start | Finish | Predecessors | Total slack | Resources | Work |
| --- | --- | --- | --- | --- | --- | --- | --- | --- | --- | --- |
| 160 | 8 | **Maintenance Handover** |  | 56d | 2017-02-10 | 2017-04-28 |  | 0d |  | 488h |
| 161 | 8.1 | Training Calendar |  | 3d | 2017-02-10 | 2017-02-14 | 129SS+20d | 0d | PM | 24h |
| 162 | 8.2 | Maintenance Vendor Selection |  | 20d | 2017-02-15 | 2017-03-14 | 161 | 0d | PM | 160h |
| 163 | 8.3 | Maintenance Vendor Engagement |  | 5d | 2017-03-15 | 2017-03-21 | 162 | 0d | PM | 40h |
| 164 | 8.4 | User Manual |  | 10d | 2017-03-22 | 2017-04-04 | 163 | 0d | Technical Writer | 80h |
| 165 | 8.5 | Administration Manual |  | 10d | 2017-04-05 | 2017-04-18 | 164 | 0d | Technical Writer | 80h |
| 166 | 8.6 | Techno Functional Handover |  | 3d | 2017-04-19 | 2017-04-21 | 165 | 0d | PM | 24h |
| 167 | 8.7 | Training Org Wide |  | 5d | 2017-04-24 | 2017-04-28 | 166 | 0d | PM | 40h |
| 168 | 8.8 | **BUGZILLA** |  | 5d | 2017-04-24 | 2017-04-28 |  | 0d |  | 40h |
| 169 | 8.8.1 | Issue Tracking BUGZILLA installation |  | 2d | 2017-04-24 | 2017-04-25 | 166 | 0d | Maintenance Vendor | 16h |
| 170 | 8.8.2 | Bugzilla accounts, training and access handover |  | 3d | 2017-04-26 | 2017-04-28 | 169 | 0d | Maintenance Vendor | 24h |
| 171 | 8.8.3 | Milestone: Project Complete | milestone | 0d | 2017-04-28 | 2017-04-28 | 170 | 0d |  |  |

Notes:
- 167: To be planned in greater detail
