# Learning Management System Implementation

Schedule from MS Project, 2015-04-06 to 2016-04-22, costs in $.
*********Copyright Info********* / * Lifetime access 50% discount for just $12 - 100+ video Lessons, Quizzes, 100+ exercise files: / * https://www.udemy.com/microsoft-project-tutorial/?couponCode=copyrightDiscount / * CONQUER Microsoft Project 2016 today! Get promotions, respect of peers and mastery of your domain. / * Approved for 10 FREE PMP PDU points from Project Management Institute PMI©. / * Copyright Srikanth R Shirodkar 2016-2020. email: srikanth.shirodkar@gmail.com / ********************************

## Calendars

- LMS Implementation Calendar: Mon-Fri 08:00-12:00, 13:00-17:00; Sat-Sun off. Exceptions (off unless hours are given): 2015-04-16 (Emancipation Day), 2015-05-25 (Memorial Day), 2015-07-03 (Independence Day), 2015-09-07 (Labor Day), 2015-10-12 (Columbus Day), 2015-11-11 (Veterans Day), 2015-11-26 (Thanksgiving), 2015-11-27 (Day after Thanksgiving), 2015-12-25 (Christmas Day), 2016-01-01 (New Years Day), 2016-01-18 (Martin Luther King Day), 2016-02-15 (Presidents Day), 2016-04-15 (Emancipation Day).

## Resources

| Resource | Rate |
| --- | --- |
| PM | 90 |
| Content Vendor | 120 |
| Test Lead | 70 |
| Mobile Vendor | 125 |
| Web Design Vendor | 100 |
| Deploy Team | 80 |
| Maintenance Vendor | 100 |
| Technical Writer | 45 |
| IT Director | 120 |
| PMO | 85 |
| Approval Board | 80 |
| IT Manager | 85 |
| Faculty Rep | 45 |
| Dean | 70 |
| Develop Team | 70 |
| Testing Team | 45 |
| Architect | 90 |
| Content Team | 45 |
| Stakeholders | 10 |

## Schedule

| ID | WBS | Task | Type | Duration | Start | Finish | Predecessors | Baseline start | Baseline finish | Baseline duration | Total slack | Constraint | Resources | Work | Cost |
| --- | --- | --- | --- | --- | --- | --- | --- | --- | --- | --- | --- | --- | --- | --- | --- |
| 1 | 1 | **Planning Phase** |  | 34d | 2015-04-06 | 2015-05-22 |  | 2015-04-06 | 2015-05-22 | 34d | 0d |  |  | 280h | 23,760 |
| 2 | 1.1 | Strategic Objectives |  | 7d | 2015-04-06 | 2015-04-14 |  | 2015-04-06 | 2015-04-14 | 7d | 0d |  | PMO | 56h | 4,760 |
| 3 | 1.2 | Budgetary Objectives |  | 5d | 2015-04-15 | 2015-04-21 | 2 | 2015-04-15 | 2015-04-21 | 5d | 0d |  | PMO | 40h | 3,400 |
| 4 | 1.3 | Compliance and Regulatory requirements |  | 6d | 2015-04-22 | 2015-04-29 | 3 | 2015-04-22 | 2015-04-29 | 6d | 0d |  | PMO | 48h | 4,080 |
| 5 | 1.4 | Partners/Suppliers/Corporate Objectives |  | 2d | 2015-04-30 | 2015-05-01 | 4 | 2015-04-30 | 2015-05-01 | 2d | 0d |  | PMO | 16h | 1,360 |
| 6 | 1.5 | Doc: Strategic Objectives document |  | 7d | 2015-05-04 | 2015-05-12 | 5 | 2015-05-04 | 2015-05-12 | 7d | 0d |  | PM | 56h | 5,040 |
| 7 | 1.6 | Review Objectives Document |  | 5d | 2015-05-13 | 2015-05-19 | 6 | 2015-05-13 | 2015-05-19 | 5d | 0d |  | Approval Board | 40h | 3,200 |
| 8 | 1.7 | Signoff Objectives |  | 3d | 2015-05-20 | 2015-05-22 | 7 | 2015-05-20 | 2015-05-22 | 3d | 0d |  | Approval Board | 24h | 1,920 |
| 9 | 1.8 | Milestone: Planning Complete | milestone | 0d | 2015-05-22 | 2015-05-22 | 8 | 2015-05-22 | 2015-05-22 |  | 0d |  |  |  |  |
| 10 | 2 | **Weekly Review Meeting** |  | 185.25d | 2015-06-01 | 2016-02-29 |  | 2015-06-01 | 2016-02-29 | 185.25d | 38.75d |  | Stakeholders | 1562h | 15,620 |
| 11 | 2.1 | Weekly Review Meeting 1 |  | 2h | 2015-06-01 | 2015-06-01 |  | 2015-06-01 | 2015-06-01 | 2h | 223.75d | start no earlier than 2015-06-01 |  |  |  |
| 12 | 2.2 | Weekly Review Meeting 2 |  | 2h | 2015-06-08 | 2015-06-08 |  | 2015-06-08 | 2015-06-08 | 2h | 218.75d | start no earlier than 2015-06-08 |  |  |  |
| 13 | 2.3 | Weekly Review Meeting 3 |  | 2h | 2015-06-15 | 2015-06-15 |  | 2015-06-15 | 2015-06-15 | 2h | 213.75d | start no earlier than 2015-06-15 |  |  |  |
| 14 | 2.4 | Weekly Review Meeting 4 |  | 2h | 2015-06-22 | 2015-06-22 |  | 2015-06-22 | 2015-06-22 | 2h | 208.75d | start no earlier than 2015-06-22 |  |  |  |
| 15 | 2.5 | Weekly Review Meeting 5 |  | 2h | 2015-06-29 | 2015-06-29 |  | 2015-06-29 | 2015-06-29 | 2h | 203.75d | start no earlier than 2015-06-29 |  |  |  |
| 16 | 2.6 | Weekly Review Meeting 6 |  | 2h | 2015-07-06 | 2015-07-06 |  | 2015-07-06 | 2015-07-06 | 2h | 199.75d | start no earlier than 2015-07-06 |  |  |  |
| 17 | 2.7 | Weekly Review Meeting 7 |  | 2h | 2015-07-13 | 2015-07-13 |  | 2015-07-13 | 2015-07-13 | 2h | 194.75d | start no earlier than 2015-07-13 |  |  |  |
| 18 | 2.8 | Weekly Review Meeting 8 |  | 2h | 2015-07-20 | 2015-07-20 |  | 2015-07-20 | 2015-07-20 | 2h | 189.75d | start no earlier than 2015-07-20 |  |  |  |
| 19 | 2.9 | Weekly Review Meeting 9 |  | 2h | 2015-07-27 | 2015-07-27 |  | 2015-07-27 | 2015-07-27 | 2h | 184.75d | start no earlier than 2015-07-27 |  |  |  |
| 20 | 2.10 | Weekly Review Meeting 10 |  | 2h | 2015-08-03 | 2015-08-03 |  | 2015-08-03 | 2015-08-03 | 2h | 179.75d | start no earlier than 2015-08-03 |  |  |  |
| 21 | 2.11 | Weekly Review Meeting 11 |  | 2h | 2015-08-10 | 2015-08-10 |  | 2015-08-10 | 2015-08-10 | 2h | 174.75d | start no earlier than 2015-08-10 |  |  |  |
| 22 | 2.12 | Weekly Review Meeting 12 |  | 2h | 2015-08-17 | 2015-08-17 |  | 2015-08-17 | 2015-08-17 | 2h | 169.75d | start no earlier than 2015-08-17 |  |  |  |
| 23 | 2.13 | Weekly Review Meeting 13 |  | 2h | 2015-08-24 | 2015-08-24 |  | 2015-08-24 | 2015-08-24 | 2h | 164.75d | start no earlier than 2015-08-24 |  |  |  |
| 24 | 2.14 | Weekly Review Meeting 14 |  | 2h | 2015-08-31 | 2015-08-31 |  | 2015-08-31 | 2015-08-31 | 2h | 159.75d | start no earlier than 2015-08-31 |  |  |  |
| 25 | 2.15 | Weekly Review Meeting 15 |  | 2h | 2015-09-08 | 2015-09-08 |  | 2015-09-08 | 2015-09-08 | 2h | 154.75d | start no earlier than 2015-09-07 |  |  |  |
| 26 | 2.16 | Weekly Review Meeting 16 |  | 2h | 2015-09-14 | 2015-09-14 |  | 2015-09-14 | 2015-09-14 | 2h | 150.75d | start no earlier than 2015-09-14 |  |  |  |
| 27 | 2.17 | Weekly Review Meeting 17 |  | 2h | 2015-09-21 | 2015-09-21 |  | 2015-09-21 | 2015-09-21 | 2h | 145.75d | start no earlier than 2015-09-21 |  |  |  |
| 28 | 2.18 | Weekly Review Meeting 18 |  | 2h | 2015-09-28 | 2015-09-28 |  | 2015-09-28 | 2015-09-28 | 2h | 140.75d | start no earlier than 2015-09-28 |  |  |  |
| 29 | 2.19 | Weekly Review Meeting 19 |  | 2h | 2015-10-05 | 2015-10-05 |  | 2015-10-05 | 2015-10-05 | 2h | 135.75d | start no earlier than 2015-10-05 |  |  |  |
| 30 | 2.20 | Weekly Review Meeting 20 |  | 2h | 2015-10-13 | 2015-10-13 |  | 2015-10-13 | 2015-10-13 | 2h | 130.75d | start no earlier than 2015-10-12 |  |  |  |
| 31 | 2.21 | Weekly Review Meeting 21 |  | 2h | 2015-10-19 | 2015-10-19 |  | 2015-10-19 | 2015-10-19 | 2h | 126.75d | start no earlier than 2015-10-19 |  |  |  |
| 32 | 2.22 | Weekly Review Meeting 22 |  | 2h | 2015-10-26 | 2015-10-26 |  | 2015-10-26 | 2015-10-26 | 2h | 121.75d | start no earlier than 2015-10-26 |  |  |  |
| 33 | 2.23 | Weekly Review Meeting 23 |  | 2h | 2015-11-02 | 2015-11-02 |  | 2015-11-02 | 2015-11-02 | 2h | 116.75d | start no earlier than 2015-11-02 |  |  |  |
| 34 | 2.24 | Weekly Review Meeting 24 |  | 2h | 2015-11-09 | 2015-11-09 |  | 2015-11-09 | 2015-11-09 | 2h | 111.75d | start no earlier than 2015-11-09 |  |  |  |
| 35 | 2.25 | Weekly Review Meeting 25 |  | 2h | 2015-11-16 | 2015-11-16 |  | 2015-11-16 | 2015-11-16 | 2h | 107.75d | start no earlier than 2015-11-16 |  |  |  |
| 36 | 2.26 | Weekly Review Meeting 26 |  | 2h | 2015-11-23 | 2015-11-23 |  | 2015-11-23 | 2015-11-23 | 2h | 102.75d | start no earlier than 2015-11-23 |  |  |  |
| 37 | 2.27 | Weekly Review Meeting 27 |  | 2h | 2015-11-30 | 2015-11-30 |  | 2015-11-30 | 2015-11-30 | 2h | 99.75d | start no earlier than 2015-11-30 |  |  |  |
| 38 | 2.28 | Weekly Review Meeting 28 |  | 2h | 2015-12-07 | 2015-12-07 |  | 2015-12-07 | 2015-12-07 | 2h | 94.75d | start no earlier than 2015-12-07 |  |  |  |
| 39 | 2.29 | Weekly Review Meeting 29 |  | 2h | 2015-12-14 | 2015-12-14 |  | 2015-12-14 | 2015-12-14 | 2h | 89.75d | start no earlier than 2015-12-14 |  |  |  |
| 40 | 2.30 | Weekly Review Meeting 30 |  | 2h | 2015-12-21 | 2015-12-21 |  | 2015-12-21 | 2015-12-21 | 2h | 84.75d | start no earlier than 2015-12-21 |  |  |  |
| 41 | 2.31 | Weekly Review Meeting 31 |  | 2h | 2015-12-28 | 2015-12-28 |  | 2015-12-28 | 2015-12-28 | 2h | 80.75d | start no earlier than 2015-12-28 |  |  |  |
| 42 | 2.32 | Weekly Review Meeting 32 |  | 2h | 2016-01-04 | 2016-01-04 |  | 2016-01-04 | 2016-01-04 | 2h | 76.75d | start no earlier than 2016-01-04 |  |  |  |
| 43 | 2.33 | Weekly Review Meeting 33 |  | 2h | 2016-01-11 | 2016-01-11 |  | 2016-01-11 | 2016-01-11 | 2h | 71.75d | start no earlier than 2016-01-11 |  |  |  |
| 44 | 2.34 | Weekly Review Meeting 34 |  | 2h | 2016-01-19 | 2016-01-19 |  | 2016-01-19 | 2016-01-19 | 2h | 66.75d | start no earlier than 2016-01-18 |  |  |  |
| 45 | 2.35 | Weekly Review Meeting 35 |  | 2h | 2016-01-25 | 2016-01-25 |  | 2016-01-25 | 2016-01-25 | 2h | 62.75d | start no earlier than 2016-01-25 |  |  |  |
| 46 | 2.36 | Weekly Review Meeting 36 |  | 2h | 2016-02-01 | 2016-02-01 |  | 2016-02-01 | 2016-02-01 | 2h | 57.75d | start no earlier than 2016-02-01 |  |  |  |
| 47 | 2.37 | Weekly Review Meeting 37 |  | 2h | 2016-02-08 | 2016-02-08 |  | 2016-02-08 | 2016-02-08 | 2h | 52.75d | start no earlier than 2016-02-08 |  |  |  |
| 48 | 2.38 | Weekly Review Meeting 38 |  | 2h | 2016-02-16 | 2016-02-16 |  | 2016-02-16 | 2016-02-16 | 2h | 47.75d | start no earlier than 2016-02-15 |  |  |  |
| 49 | 2.39 | Weekly Review Meeting 39 |  | 2h | 2016-02-22 | 2016-02-22 |  | 2016-02-22 | 2016-02-22 | 2h | 43.75d | start no earlier than 2016-02-22 |  |  |  |
| 50 | 2.40 | Weekly Review Meeting 40 |  | 2h | 2016-02-29 | 2016-02-29 |  | 2016-02-29 | 2016-02-29 | 2h | 38.75d | start no earlier than 2016-02-29 |  |  |  |

| ID | WBS | Task | Type | Duration | Start | Finish | Predecessors | Baseline start | Baseline finish | Baseline duration | Total slack | Free slack | Resources | Work | Cost |
| --- | --- | --- | --- | --- | --- | --- | --- | --- | --- | --- | --- | --- | --- | --- | --- |
| 51 | 3 | **Detailed Design Phase** |  | 71d | 2015-05-25 | 2015-09-02 |  | 2015-05-25 | 2015-09-02 | 71d | 0d |  |  | 824h | 64,760 |
| 52 | 3.1 | Technology Considerations |  | 3d | 2015-05-25 | 2015-05-27 | 9 | 2015-05-25 | 2015-05-27 | 3d | 0d |  | IT Manager | 24h | 2,040 |
| 53 | 3.2 | Integration Considerations |  | 6d | 2015-05-28 | 2015-06-04 | 52 | 2015-05-28 | 2015-06-04 | 6d | 0d |  | IT Manager | 48h | 4,080 |
| 54 | 3.3 | Non Functional Requirements |  | 6d | 2015-06-05 | 2015-06-12 | 53 | 2015-06-05 | 2015-06-12 | 6d | 0d |  | IT Director | 48h | 5,760 |
| 55 | 3.4 | Administrative Needs and Roles |  | 4d | 2015-06-15 | 2015-06-18 | 54 | 2015-06-15 | 2015-06-18 | 4d | 0d |  | IT Manager | 32h | 2,720 |
| 56 | 3.5 | RACI Matrix for LMS - Org wide |  | 6d | 2015-06-19 | 2015-06-26 | 55 | 2015-06-19 | 2015-06-26 | 6d | 0d |  | PMO | 48h | 4,080 |
| 57 | 3.6 | Content Strategy |  | 2w | 2015-06-29 | 2015-07-10 | 56 | 2015-06-29 | 2015-07-10 | 2w | 0d |  | IT Manager; Faculty Rep; Dean | 240h | 16,000 |
| 58 | 3.7 | Marketing Requirements |  | 1w | 2015-07-13 | 2015-07-17 | 57 | 2015-07-13 | 2015-07-17 | 1w | 0d |  | PMO | 40h | 3,400 |
| 59 | 3.8 | Deployment Plan (rollout to all colleges) |  | 1w | 2015-07-20 | 2015-07-24 | 58 | 2015-07-20 | 2015-07-24 | 1w | 0d |  | IT Manager | 40h | 3,400 |
| 60 | 3.9 | Doc: Functional Specification Document (FSD) |  | 1w | 2015-07-27 | 2015-07-31 | 59 | 2015-07-27 | 2015-07-31 | 1w | 0d |  | Technical Writer | 40h | 1,800 |
| 61 | 3.10 | Review: FSD |  | 2d | 2015-08-03 | 2015-08-04 | 60 | 2015-08-03 | 2015-08-04 | 2d | 0d |  | IT Director | 16h | 1,920 |
| 62 | 3.11 | Signoff: FSD |  | 2d | 2015-08-05 | 2015-08-06 | 61 | 2015-08-05 | 2015-08-06 | 2d | 0d |  | IT Director | 16h | 1,920 |
| 63 | 3.12 | Doc: Technical Specifications Document (TSD) |  | 5d | 2015-08-07 | 2015-08-13 | 62 | 2015-08-07 | 2015-08-13 | 5d | 0d |  | IT Manager | 40h | 3,400 |
| 64 | 3.13 | Review: TSD |  | 2d | 2015-08-14 | 2015-08-17 | 63 | 2015-08-14 | 2015-08-17 | 2d | 0d |  | IT Director | 16h | 1,920 |
| 65 | 3.14 | Signoff: TSD |  | 2d | 2015-08-18 | 2015-08-19 | 64 | 2015-08-18 | 2015-08-19 | 2d | 0d |  | IT Director | 16h | 1,920 |
| 66 | 3.15 | Content Strategy Document (CSD) |  | 2w | 2015-08-20 | 2015-09-02 | 65 | 2015-08-20 | 2015-09-02 | 2w | 0d |  | Faculty Rep; IT Manager | 160h | 10,400 |
| 67 | 3.16 | Milestone: Detailed Design Complete | milestone | 0d | 2015-09-02 | 2015-09-02 | 66 | 2015-09-02 | 2015-09-02 |  | 0d |  |  |  |  |
| 68 | 4 | **Implementation Phase** |  | 83d | 2015-09-03 | 2016-01-06 |  | 2015-09-03 | 2016-01-06 | 83d | 0d |  |  | 2320h | 225,760 |
| 69 | 4.1 | Testing Server Setup |  | 2d | 2015-09-03 | 2015-09-04 | 67 | 2015-09-03 | 2015-09-04 | 2d | 88d | 0d | Deploy Team | 16h | 1,280 |
| 70 | 4.2 | Development Server Setup |  | 2d | 2015-09-07 | 2015-09-08 | 69 | 2015-09-07 | 2015-09-08 | 2d | 88d | 0d | Deploy Team | 16h | 1,280 |
| 71 | 4.3 | Install: Moodle Test installation |  | 1d | 2015-09-09 | 2015-09-09 | 70 | 2015-09-09 | 2015-09-09 | 1d | 89d | 0d | Deploy Team | 8h | 640 |
| 72 | 4.4 | Database design |  | 5d | 2015-09-10 | 2015-09-16 | 71 | 2015-09-10 | 2015-09-16 | 5d | 89d | 0d | Architect | 40h | 3,600 |
| 73 | 4.5 | Doc: Upgrade Strategy Document (USD) |  | 5d | 2015-09-17 | 2015-09-23 | 72 | 2015-09-17 | 2015-09-23 | 5d | 89d | 0d | Architect | 40h | 3,600 |
| 74 | 4.6 | **Moodle: LMS Structure** |  | 19d | 2015-09-24 | 2015-10-21 |  | 2015-09-24 | 2015-10-21 | 19d | 89d |  |  | 160h | 11,200 |
| 75 | 4.6.1 | Home Page |  | 3d | 2015-09-24 | 2015-09-28 | 73 | 2015-09-24 | 2015-09-28 | 3d | 89d | 0d | Develop Team | 24h | 1,680 |
| 76 | 4.6.2 | Main Landing Page |  | 8d | 2015-09-29 | 2015-10-08 | 75 | 2015-09-29 | 2015-10-08 | 8d | 88d | 0d | Develop Team | 64h | 4,480 |
| 77 | 4.6.3 | Institution Landing Pages |  | 5d | 2015-10-09 | 2015-10-15 | 76 | 2015-10-09 | 2015-10-15 | 5d | 88d | 0d | Develop Team | 40h | 2,800 |
| 78 | 4.6.4 | Course Landing Pages |  | 4d | 2015-10-16 | 2015-10-21 | 77 | 2015-10-16 | 2015-10-21 | 4d | 89d | 0d | Develop Team | 32h | 2,240 |

| ID | WBS | Task | Type | Duration | Start | Finish | Predecessors | Baseline start | Baseline finish | Baseline duration | Total slack | Free slack | Resources | Work | Cost |
| --- | --- | --- | --- | --- | --- | --- | --- | --- | --- | --- | --- | --- | --- | --- | --- |
| 79 | 4.7 | **Moodle: Course Design and Planning** |  | 12d | 2015-10-22 | 2015-11-06 |  | 2015-10-22 | 2015-11-06 | 12d | 89d |  |  | 96h | 4,320 |
| 80 | 4.7.1 | Courses Upload |  | 5d | 2015-10-22 | 2015-10-28 | 78 | 2015-10-22 | 2015-10-28 | 5d | 89d | 0d | Content Team | 40h | 1,800 |
| 81 | 4.7.2 | Courses Structuring |  | 4d | 2015-10-29 | 2015-11-03 | 80 | 2015-10-29 | 2015-11-03 | 4d | 89d | 0d | Content Team | 32h | 1,440 |
| 82 | 4.7.3 | Courses Support Material Upload |  | 3d | 2015-11-04 | 2015-11-06 | 81 | 2015-11-04 | 2015-11-06 | 3d | 89d | 0d | Content Team | 24h | 1,080 |
| 83 | 4.8 | **Moodle: Course Creation** |  | 11d | 2015-11-09 | 2015-11-24 |  | 2015-11-09 | 2015-11-24 | 11d | 89d |  |  | 96h | 4,320 |
| 84 | 4.8.1 | Course Space Creation |  | 5d | 2015-11-09 | 2015-11-13 | 82 | 2015-11-09 | 2015-11-13 | 5d | 89d | 0d | Content Team | 40h | 1,800 |
| 85 | 4.8.2 | Course Pages |  | 4d | 2015-11-16 | 2015-11-19 | 84 | 2015-11-16 | 2015-11-19 | 4d | 90d | 0d | Content Team | 32h | 1,440 |
| 86 | 4.8.3 | Assessment Requirements |  | 3d | 2015-11-20 | 2015-11-24 | 85 | 2015-11-20 | 2015-11-24 | 3d | 90d | 0d | Faculty Rep | 24h | 1,080 |
| 87 | 4.9 | **Moodle: Performance and Control Considerations** |  | 10d | 2015-11-25 | 2015-12-10 |  | 2015-11-25 | 2015-12-10 | 10d | 90d |  |  | 96h | 6,120 |
| 88 | 4.9.1 | Automated and Manual Communications setup |  | 5d | 2015-11-25 | 2015-12-01 | 86 | 2015-11-25 | 2015-12-01 | 5d | 90d | 0d | Architect | 40h | 3,600 |
| 89 | 4.9.2 | Support Pages Configuration |  | 4d | 2015-12-02 | 2015-12-07 | 88 | 2015-12-02 | 2015-12-07 | 4d | 91d | 0d | Faculty Rep | 32h | 1,440 |
| 90 | 4.9.3 | Course Release Strategy |  | 3d | 2015-12-08 | 2015-12-10 | 89 | 2015-12-08 | 2015-12-10 | 3d | 91d |  | Content Team | 24h | 1,080 |
| 91 | 4.10 | **LMS User Experience** |  | 32d | 2015-09-03 | 2015-10-20 |  | 2015-09-03 | 2015-10-20 | 32d | 51d |  |  | 272h | 27,200 |
| 92 | 4.10.1 | Doc: UX Design document (UXD) |  | 5d | 2015-09-03 | 2015-09-09 | 67 | 2015-09-03 | 2015-09-09 | 5d | 53d | 0d | Web Design Vendor | 40h | 4,000 |
| 93 | 4.10.2 | Review: UXD |  | 2d | 2015-09-10 | 2015-09-11 | 92 | 2015-09-10 | 2015-09-11 | 2d | 52d | 0d | Web Design Vendor | 16h | 1,600 |
| 94 | 4.10.3 | Signoff: UXD |  | 2d | 2015-09-14 | 2015-09-15 | 93 | 2015-09-14 | 2015-09-15 | 2d | 52d | 0d | Web Design Vendor | 16h | 1,600 |
| 95 | 4.10.4 | Custom Theme Development |  | 2w | 2015-09-16 | 2015-09-29 | 94 | 2015-09-16 | 2015-09-29 | 2w | 52d | 0d | Web Design Vendor | 80h | 8,000 |
| 96 | 4.10.5 | Department-wide custom themes |  | 1w | 2015-09-30 | 2015-10-06 | 95 | 2015-09-30 | 2015-10-06 | 1w | 52d | 0d | Web Design Vendor | 40h | 4,000 |
| 97 | 4.10.6 | Logo and Branding requirements |  | 5d | 2015-10-07 | 2015-10-13 | 96 | 2015-10-07 | 2015-10-13 | 5d | 52d | 0d | Web Design Vendor | 40h | 4,000 |
| 98 | 4.10.7 | Marketing UX reqts |  | 5d | 2015-10-14 | 2015-10-20 | 97 | 2015-10-14 | 2015-10-20 | 5d | 51d | 0d | Web Design Vendor | 40h | 4,000 |
| 99 | 4.10.8 | Milestone: UX complete | milestone | 0d | 2015-10-20 | 2015-10-20 | 98 | 2015-10-20 | 2015-10-20 |  | 51d |  | Web Design Vendor |  |  |
| 100 | 4.11 | **LMS Content Migration** |  | 83d | 2015-09-03 | 2016-01-06 |  | 2015-09-03 | 2016-01-06 | 83d | 0d |  |  | 720h | 84,000 |
| 101 | 4.11.1 | Content Vendor Selection |  | 5d | 2015-09-03 | 2015-09-09 | 67 | 2015-09-03 | 2015-09-09 | 5d | 0d |  | PM | 40h | 3,600 |
| 102 | 4.11.2 | Content Vendor Engage |  | 5d | 2015-09-10 | 2015-09-16 | 101 | 2015-09-10 | 2015-09-16 | 5d | 0d |  | PM | 40h | 3,600 |
| 103 | 4.11.3 | Migrate SCORM Content |  | 10d | 2015-09-17 | 2015-09-30 | 102 | 2015-09-17 | 2015-09-30 | 10d | 0d |  | Content Vendor | 80h | 9,600 |
| 104 | 4.11.4 | Vendonr: New Content Creation |  | 60d | 2015-10-01 | 2015-12-23 | 103 | 2015-10-01 | 2015-12-23 | 60d | 0d |  | Content Vendor | 480h | 57,600 |
| 105 | 4.11.5 | Vendor: New content Upload |  | 10d | 2015-12-24 | 2016-01-06 | 104 | 2015-12-24 | 2016-01-06 | 10d | 0d |  | Content Vendor | 80h | 9,600 |
| 106 | 4.11.6 | Milestone: Migration done | milestone | 0d | 2016-01-06 | 2016-01-06 | 105 | 2016-01-06 | 2016-01-06 |  | 0d |  | Content Vendor |  |  |

| ID | WBS | Task | Type | Duration | Start | Finish | Predecessors | Baseline start | Baseline finish | Baseline duration | Total slack | Free slack | Resources | Work | Cost |
| --- | --- | --- | --- | --- | --- | --- | --- | --- | --- | --- | --- | --- | --- | --- | --- |
| 107 | 4.12 | **Mobile App Development** |  | 56d | 2015-09-25 | 2015-12-17 |  | 2015-09-25 | 2015-12-17 | 56d | 12d |  |  | 480h | 58,600 |
| 108 | 4.12.1 | Mobile Dev Vendor Selection |  | 1w | 2015-09-25 | 2015-10-01 | 67FS+15d | 2015-09-25 | 2015-10-01 | 1w | 13d | 0d | PM | 40h | 3,600 |
| 109 | 4.12.2 | Requirements and signoff |  | 2w | 2015-10-02 | 2015-10-15 | 108 | 2015-10-02 | 2015-10-15 | 2w | 13d | 0d | Mobile Vendor | 80h | 10,000 |
| 110 | 4.12.3 | Notifications |  | 4d | 2015-10-16 | 2015-10-21 | 109 | 2015-10-16 | 2015-10-21 | 4d | 14d | 0d | Mobile Vendor | 32h | 4,000 |
| 111 | 4.12.4 | Calendar |  | 2d | 2015-10-22 | 2015-10-23 | 110 | 2015-10-22 | 2015-10-23 | 2d | 13d | 0d | Mobile Vendor | 16h | 2,000 |
| 112 | 4.12.5 | Quiz Engine |  | 15d | 2015-10-26 | 2015-11-13 | 111 | 2015-10-26 | 2015-11-13 | 15d | 12d | 0d | Mobile Vendor | 120h | 15,000 |
| 113 | 4.12.6 | Annual Time Table |  | 2d | 2015-11-16 | 2015-11-17 | 112 | 2015-11-16 | 2015-11-17 | 2d | 12d | 0d | Mobile Vendor | 16h | 2,000 |
| 114 | 4.12.7 | Messaging |  | 1w | 2015-11-18 | 2015-11-24 | 113 | 2015-11-18 | 2015-11-24 | 1w | 12d | 0d | Mobile Vendor | 40h | 5,000 |
| 115 | 4.12.8 | Social Integration |  | 2d | 2015-11-25 | 2015-11-26 | 114 | 2015-11-25 | 2015-11-26 | 2d | 12d | 0d | Mobile Vendor | 16h | 2,000 |
| 116 | 4.12.9 | Usability Testing |  | 5d | 2015-11-27 | 2015-12-03 | 115 | 2015-11-27 | 2015-12-03 | 5d | 13d | 0d | Mobile Vendor | 40h | 5,000 |
| 117 | 4.12.10 | Functional Testing |  | 5d | 2015-12-04 | 2015-12-10 | 116 | 2015-12-04 | 2015-12-10 | 5d | 13d | 0d | Mobile Vendor | 40h | 5,000 |
| 118 | 4.12.11 | Integration testing |  | 5d | 2015-12-11 | 2015-12-17 | 117 | 2015-12-11 | 2015-12-17 | 5d | 12d | 0d | Mobile Vendor | 40h | 5,000 |
| 119 | 4.12.12 | Milestone: Mobile dev complete | milestone | 0d | 2015-12-17 | 2015-12-17 | 118 | 2015-12-17 | 2015-12-17 |  | 12d |  | Mobile Vendor |  |  |
| 120 | 4.13 | **Testing Plan and Setup** |  | 32d | 2015-10-19 | 2015-12-04 |  | 2015-10-19 | 2015-12-04 | 32d | 21d |  |  | 280h | 19,600 |
| 121 | 4.13.1 | Doc: Test Specification Document (TSD) |  | 2w | 2015-10-19 | 2015-10-30 | 67FS+30d | 2015-10-19 | 2015-10-30 | 2w | 20d | 0d | Test Lead | 80h | 5,600 |
| 122 | 4.13.2 | Test team setup |  | 5d | 2015-11-02 | 2015-11-06 | 121 | 2015-11-02 | 2015-11-06 | 5d | 20d | 0d | Test Lead | 40h | 2,800 |
| 123 | 4.13.3 | Review: TSD |  | 3d | 2015-11-09 | 2015-11-11 | 122 | 2015-11-09 | 2015-11-11 | 3d | 20d | 0d | Test Lead | 24h | 1,680 |
| 124 | 4.13.4 | Signoff: TSD |  | 2d | 2015-11-12 | 2015-11-13 | 123 | 2015-11-12 | 2015-11-13 | 2d | 21d | 0d | Test Lead | 16h | 1,120 |
| 125 | 4.13.5 | Content Test Strategy |  | 2w | 2015-11-16 | 2015-11-27 | 124 | 2015-11-16 | 2015-11-27 | 2w | 21d | 0d | Test Lead | 80h | 5,600 |
| 126 | 4.13.6 | Usability Test Strategy |  | 1w | 2015-11-30 | 2015-12-04 | 125 | 2015-11-30 | 2015-12-04 | 1w | 21d |  | Test Lead | 40h | 2,800 |
| 127 | 4.14 | Milestone: Implementation Complete | milestone | 0d | 2016-01-06 | 2016-01-06 | 126, 106, 119, 99 | 2016-01-06 | 2016-01-06 |  | 0d |  |  |  |  |
| 128 | 5 | **Integration Phase** |  | 52d | 2016-01-07 | 2016-03-22 |  | 2016-01-07 | 2016-03-22 | 52d | 0d |  |  | 432h | 34,560 |
| 129 | 5.1 | Single Sign On (SSO) Setup |  | 3d | 2016-01-07 | 2016-01-11 | 127 | 2016-01-07 | 2016-01-11 | 3d | 0d |  | Deploy Team | 24h | 1,920 |
| 130 | 5.2 | Student Information System (SIS) Setup |  | 5d | 2016-01-12 | 2016-01-18 | 129 | 2016-01-12 | 2016-01-18 | 5d | 2d | 0d | Deploy Team | 40h | 3,200 |
| 131 | 5.3 | Datewarehousing Integration (Learning Analytics) |  | 10d | 2016-01-19 | 2016-02-01 | 130 | 2016-01-19 | 2016-02-01 | 10d | 2d | 0d | Deploy Team | 80h | 6,400 |
| 132 | 5.4 | SAP Integration |  | 15d | 2016-02-02 | 2016-02-22 | 131 | 2016-02-02 | 2016-02-22 | 15d | 2d | 0d | Deploy Team | 120h | 9,600 |
| 133 | 5.5 | Accounting Software Setup |  | 5d | 2016-02-23 | 2016-02-29 | 132 | 2016-02-23 | 2016-02-29 | 5d | 2d | 0d | Deploy Team | 40h | 3,200 |

Notes:
- 121: Start writing the Test Plan after the detailed design is complete - and implementation has started
- 127: Note the multiple dependencies for this milestone to complete

| ID | WBS | Task | Type | Duration | Start | Finish | Predecessors | Baseline start | Baseline finish | Baseline duration | Total slack | Free slack | Resources | Work | Cost |
| --- | --- | --- | --- | --- | --- | --- | --- | --- | --- | --- | --- | --- | --- | --- | --- |
| 134 | 5.6 | **STAGING SERVER SETUP** |  | 16d | 2016-03-01 | 2016-03-22 |  | 2016-03-01 | 2016-03-22 | 16d | 2d |  |  | 128h | 10,240 |
| 135 | 5.6.1 | Server setup, Redundancy setup |  | 3d | 2016-03-01 | 2016-03-03 | 133 | 2016-03-01 | 2016-03-03 | 3d | 2d | 0d | Deploy Team | 24h | 1,920 |
| 136 | 5.6.2 | Database Configuration |  | 3d | 2016-03-04 | 2016-03-08 | 135 | 2016-03-04 | 2016-03-08 | 3d | 2d | 0d | Deploy Team | 24h | 1,920 |
| 137 | 5.6.3 | LMS Installation |  | 2d | 2016-03-09 | 2016-03-10 | 136 | 2016-03-09 | 2016-03-10 | 2d | 2d | 0d | Deploy Team | 16h | 1,280 |
| 138 | 5.6.4 | Course Data Migration |  | 3d | 2016-03-11 | 2016-03-15 | 137 | 2016-03-11 | 2016-03-15 | 3d | 2d | 0d | Deploy Team | 24h | 1,920 |
| 139 | 5.6.5 | Student Data Import |  | 3d | 2016-03-16 | 2016-03-18 | 138 | 2016-03-16 | 2016-03-18 | 3d | 2d | 0d | Deploy Team | 24h | 1,920 |
| 140 | 5.6.6 | RBAC Setup and testing |  | 2d | 2016-03-21 | 2016-03-22 | 139 | 2016-03-21 | 2016-03-22 | 2d | 2d | 0d | Deploy Team | 16h | 1,280 |
| 141 | 5.6.7 | Milestone: Integration Phase Complete | milestone | 0d | 2016-03-22 | 2016-03-22 | 140 | 2016-03-22 | 2016-03-22 |  | 2d | 0d |  |  |  |
| 142 | 6 | **VERIFICATION and STAGING** |  | 118d | 2015-10-22 | 2016-04-13 |  | 2015-10-19 | 2016-04-11 | 118d | 6d |  |  | 1080h | 56,600 |
| 143 | 6.1 | Unit Testing of all modules |  | 2mo | 2015-10-22 | 2015-12-16 | 68SS+2.5% | 2015-10-19 | 2015-12-14 | 2mo | 6d | 0d | Develop Team | 320h | 22,400 |
| 144 | 6.2 | Functional Testing |  | 3w | 2015-12-17 | 2016-01-06 | 143 | 2015-12-14 | 2016-01-04 | 3w | 6d | 0d | Testing Team | 120h | 5,400 |
| 145 | 6.3 | Installation and Deploy Testing |  | 2w | 2016-01-07 | 2016-01-20 | 144 | 2016-01-04 | 2016-01-18 | 2w | 7d | 0d | Testing Team | 80h | 3,600 |
| 146 | 6.4 | Performance Testing |  | 2w | 2016-01-21 | 2016-02-03 | 145 | 2016-01-18 | 2016-02-01 | 2w | 7d | 0d | Testing Team | 80h | 3,600 |
| 147 | 6.5 | Usability Testing |  | 2w | 2016-02-04 | 2016-02-17 | 146 | 2016-02-01 | 2016-02-15 | 2w | 7d | 0d | Testing Team | 80h | 3,600 |
| 148 | 6.6 | Alpha Testing |  | 2w | 2016-02-18 | 2016-03-02 | 147 | 2016-02-15 | 2016-02-29 | 2w | 7d | 0d | Testing Team | 80h | 3,600 |
| 149 | 6.7 | UAT Scripting |  | 2w | 2016-03-03 | 2016-03-16 | 148 | 2016-02-29 | 2016-03-14 | 2w | 7d | 0d | Testing Team | 80h | 3,600 |
| 150 | 6.8 | UAT cases review and approval |  | 2w | 2016-03-17 | 2016-03-30 | 149 | 2016-03-14 | 2016-03-28 | 2w | 7d | 0d | Testing Team | 80h | 3,600 |
| 151 | 6.9 | User Acceptance Testing |  | 2w | 2016-03-31 | 2016-04-13 | 150 | 2016-03-28 | 2016-04-11 | 2w | 6d | 0d | Testing Team; Faculty Rep | 160h | 7,200 |
| 152 | 6.10 | Milestone: Testing Complete | milestone | 0d | 2016-04-13 | 2016-04-13 | 151 | 2016-04-11 | 2016-04-11 |  | 6d | 19.25d |  |  |  |
| 153 | 7 | **PRODUCTION DEPLOYMENT** |  | 20d | 2016-03-23 | 2016-04-20 |  | 2016-03-23 | 2016-04-20 | 20d | 2d |  |  | 168h | 13,440 |
| 154 | 7.1 | Hardware, Software, Database Setup, Configuration |  | 5d | 2016-03-23 | 2016-03-29 | 141 | 2016-03-23 | 2016-03-29 | 5d | 2d | 0d | Deploy Team | 40h | 3,200 |
| 155 | 7.2 | Course Data Migration |  | 6d | 2016-03-30 | 2016-04-06 | 154 | 2016-03-30 | 2016-04-06 | 6d | 2d | 0d | Deploy Team | 48h | 3,840 |
| 156 | 7.3 | Student Data Migration |  | 4d | 2016-04-07 | 2016-04-12 | 155 | 2016-04-07 | 2016-04-12 | 4d | 2d | 0d | Deploy Team | 32h | 2,560 |
| 157 | 7.4 | Course Creation - all Colleges |  | 5d | 2016-04-13 | 2016-04-19 | 156 | 2016-04-13 | 2016-04-19 | 5d | 2d | 0d | Deploy Team | 40h | 3,200 |
| 158 | 7.5 | Roles and Accounts |  | 1d | 2016-04-20 | 2016-04-20 | 157 | 2016-04-20 | 2016-04-20 | 1d | 2d | 0d | Deploy Team | 8h | 640 |
| 159 | 7.6 | Milestone: Prod Deploy Complete | milestone | 0d | 2016-04-20 | 2016-04-20 | 158 | 2016-04-20 | 2016-04-20 |  | 2d |  |  |  |  |

Notes:
- 144: Testing can start when Implementation has completed atleast 25%

| ID | WBS | Task | Type | Duration | Start | Finish | Predecessors | Baseline start | Baseline finish | Baseline duration | Total slack | Resources | Work | Cost |
| --- | --- | --- | --- | --- | --- | --- | --- | --- | --- | --- | --- | --- | --- | --- |
| 160 | 8 | **Maintenance Handover** |  | 54d | 2016-02-05 | 2016-04-22 |  | 2016-02-05 | 2016-04-22 | 54d | 0d |  | 488h | 37,120 |
| 161 | 8.1 | Training Calendar |  | 3d | 2016-02-05 | 2016-02-09 | 129SS+20d | 2016-02-05 | 2016-02-09 | 3d | 0d | PM | 24h | 2,160 |
| 162 | 8.2 | Maintenance Vendor Selection |  | 20d | 2016-02-10 | 2016-03-08 | 161 | 2016-02-10 | 2016-03-08 | 20d | 0d | PM | 160h | 14,400 |
| 163 | 8.3 | Maintenance Vendor Engagement |  | 5d | 2016-03-09 | 2016-03-15 | 162 | 2016-03-09 | 2016-03-15 | 5d | 0d | PM | 40h | 3,600 |
| 164 | 8.4 | User Manual |  | 10d | 2016-03-16 | 2016-03-29 | 163 | 2016-03-16 | 2016-03-29 | 10d | 0d | Technical Writer | 80h | 3,600 |
| 165 | 8.5 | Administration Manual |  | 10d | 2016-03-30 | 2016-04-12 | 164 | 2016-03-30 | 2016-04-12 | 10d | 0d | Technical Writer | 80h | 3,600 |
| 166 | 8.6 | Techno Functional Handover |  | 3d | 2016-04-13 | 2016-04-15 | 165 | 2016-04-13 | 2016-04-15 | 3d | 0d | PM | 24h | 2,160 |
| 167 | 8.7 | Training Org Wide |  | 5d | 2016-04-18 | 2016-04-22 | 166 | 2016-04-18 | 2016-04-22 | 5d | 0d | PM | 40h | 3,600 |
| 168 | 8.8 | **BUGZILLA** |  | 5d | 2016-04-18 | 2016-04-22 |  | 2016-04-18 | 2016-04-22 | 5d | 0d |  | 40h | 4,000 |
| 169 | 8.8.1 | Issue Tracking BUGZILLA installation |  | 2d | 2016-04-18 | 2016-04-19 | 166 | 2016-04-18 | 2016-04-19 | 2d | 0d | Maintenance Vendor | 16h | 1,600 |
| 170 | 8.8.2 | Bugzilla accounts, training and access handover |  | 3d | 2016-04-20 | 2016-04-22 | 169 | 2016-04-20 | 2016-04-22 | 3d | 0d | Maintenance Vendor | 24h | 2,400 |
| 171 | 8.8.3 | Milestone: Project Complete | milestone | 0d | 2016-04-22 | 2016-04-22 | 170 | 2016-04-22 | 2016-04-22 |  | 0d |  |  |  |

Notes:
- 167: To be planned in greater detail
