# Learning Management System Implementation

Schedule from MS Project, 2015-04-06 to 2016-04-28, status date 2015-08-31, costs in $, A marks actual dates.
*********Copyright Info********* / * Lifetime access 50% discount for just $12 - 100+ video Lessons, Quizzes, 100+ exercise files: / * https://www.udemy.com/microsoft-project-tutorial/?couponCode=copyrightDiscount / * CONQUER Microsoft Project 2016 today! Get promotions, respect of peers and mastery of your domain. / * Approved for 10 FREE PMP PDU points from Project Management Institute PMI©. / * Copyright Srikanth R Shirodkar 2016-2020. email: srikanth.shirodkar@gmail.com / ********************************

## Calendars

- LMS Implementation Calendar: Mon-Fri 08:00-12:00, 13:00-17:00; Sat-Sun off. Exceptions (off unless hours are given): 2015-04-16 (Emancipation Day), 2015-05-25 (Memorial Day), 2015-07-03 (Independence Day), 2015-09-07 (Labor Day), 2015-10-12 (Columbus Day), 2015-11-11 (Veterans Day), 2015-11-26 (Thanksgiving), 2015-11-27 (Day after Thanksgiving), 2015-12-25 (Christmas Day), 2016-01-01 (New Years Day), 2016-01-18 (Martin Luther King Day), 2016-02-15 (Presidents Day), 2016-04-15 (Emancipation Day).

## Resources

| Resource | Rate |
| --- | --- |
| PM | 90 |
| Content Vendor | 120 |
| Test Lead | 70 |
| Mobile Vendor | 125 |
| Web Design Vendor | 100 |
| Deploy Team | 80 |
| Maintenance Vendor | 100 |
| Technical Writer | 45 |
| IT Director | 120 |
| PMO | 85 |
| Approval Board | 80 |
| IT Manager | 85 |
| Faculty Rep | 45 |
| Dean | 70 |
| Develop Team | 70 |
| Testing Team | 45 |
| Architect | 90 |
| Content Team | 45 |
| Stakeholders | 10 |

## Schedule

| ID | WBS | Task | Type | Duration | Start | Finish | Predecessors | Complete | Remaining | Baseline start | Baseline finish | Baseline duration | Baseline 1 start | Baseline 1 finish | Total slack | Constraint | Resources | Work | Actual work | Cost | Baseline cost | Actual cost |
| --- | --- | --- | --- | --- | --- | --- | --- | --- | --- | --- | --- | --- | --- | --- | --- | --- | --- | --- | --- | --- | --- | --- |
| 1 | 1 | **Planning Phase** |  | 34d | 2015-04-06 A | 2015-05-25 A |  | 100% |  | 2015-04-06 | 2015-05-22 | 34d | 2015-04-06 | 2015-05-25 |  |  |  | 288h | 288h | 24,400 | 23,760 | 24,400 |
| 2 | 1.1 | Strategic Objectives |  | 7d | 2015-04-06 A | 2015-04-14 A |  | 100% |  | 2015-04-06 | 2015-04-14 | 7d | 2015-04-06 | 2015-04-14 |  |  | PMO | 56h | 56h | 4,760 | 4,760 | 4,760 |
| 3 | 1.2 | Budgetary Objectives |  | 5d | 2015-04-15 A | 2015-04-21 A | 2 | 100% |  | 2015-04-15 | 2015-04-21 | 5d | 2015-04-15 | 2015-04-21 |  |  | PMO | 40h | 40h | 3,400 | 3,400 | 3,400 |
| 4 | 1.3 | Compliance and Regulatory requirements |  | 6d | 2015-04-22 A | 2015-04-29 A | 3 | 100% |  | 2015-04-22 | 2015-04-29 | 6d | 2015-04-22 | 2015-04-29 |  |  | PMO | 48h | 48h | 4,080 | 4,080 | 4,080 |
| 5 | 1.4 | Partners/Suppliers/Corporate Objectives |  | 2d | 2015-04-30 A | 2015-05-01 A | 4 | 100% |  | 2015-04-30 | 2015-05-01 | 2d | 2015-04-30 | 2015-05-01 |  |  | PMO | 16h | 16h | 1,360 | 1,360 | 1,360 |
| 6 | 1.5 | Doc: Strategic Objectives document |  | 7d | 2015-05-04 A | 2015-05-12 A | 5 | 100% |  | 2015-05-04 | 2015-05-12 | 7d | 2015-05-04 | 2015-05-12 |  |  | PM | 56h | 56h | 5,040 | 5,040 | 5,040 |
| 7 | 1.6 | Review Objectives Document |  | 5d | 2015-05-13 A | 2015-05-19 A | 6 | 100% |  | 2015-05-13 | 2015-05-19 | 5d | 2015-05-13 | 2015-05-19 |  |  | Approval Board | 40h | 40h | 3,200 | 3,200 | 3,200 |
| 8 | 1.7 | Signoff Objectives |  | 4d | 2015-05-20 A | 2015-05-25 A | 7 | 100% |  | 2015-05-20 | 2015-05-22 | 3d | 2015-05-20 | 2015-05-25 |  |  | Approval Board | 32h | 32h | 2,560 | 1,920 | 2,560 |
| 9 | 1.8 | Milestone: Planning Complete | milestone | 0d | 2015-05-25 A | 2015-05-25 A | 8 | 100% |  | 2015-05-22 | 2015-05-22 |  | 2015-05-25 | 2015-05-25 |  |  |  |  |  |  |  |  |
| 10 | 2 | **Weekly Review Meeting** |  | 185.25d | 2015-06-01 A | 2016-02-29 |  | 13% | 162.09d | 2015-06-01 | 2016-02-29 | 185.25d | 2015-06-01 | 2016-02-29 | 42.75d |  | Stakeholders | 1562h | 195.25h | 15,620 | 15,620 | 1,952.5 |
| 11 | 2.1 | Weekly Review Meeting 1 |  | 2h | 2015-06-01 A | 2015-06-01 A |  | 100% |  | 2015-06-01 | 2015-06-01 | 2h | 2015-06-01 | 2015-06-01 |  | start no earlier than 2015-06-01 |  |  |  |  |  |  |
| 12 | 2.2 | Weekly Review Meeting 2 |  | 2h | 2015-06-08 A | 2015-06-08 A |  | 100% |  | 2015-06-08 | 2015-06-08 | 2h | 2015-06-08 | 2015-06-08 |  | start no earlier than 2015-06-08 |  |  |  |  |  |  |
| 13 | 2.3 | Weekly Review Meeting 3 |  | 2h | 2015-06-15 A | 2015-06-15 A |  | 100% |  | 2015-06-15 | 2015-06-15 | 2h | 2015-06-15 | 2015-06-15 |  | start no earlier than 2015-06-15 |  |  |  |  |  |  |
| 14 | 2.4 | Weekly Review Meeting 4 |  | 2h | 2015-06-22 A | 2015-06-22 A |  | 100% |  | 2015-06-22 | 2015-06-22 | 2h | 2015-06-22 | 2015-06-22 |  | start no earlier than 2015-06-22 |  |  |  |  |  |  |
| 15 | 2.5 | Weekly Review Meeting 5 |  | 2h | 2015-06-29 A | 2015-06-29 A |  | 100% |  | 2015-06-29 | 2015-06-29 | 2h | 2015-06-29 | 2015-06-29 |  | start no earlier than 2015-06-29 |  |  |  |  |  |  |
| 16 | 2.6 | Weekly Review Meeting 6 |  | 2h | 2015-07-06 | 2015-07-06 |  |  |  | 2015-07-06 | 2015-07-06 | 2h | 2015-07-06 | 2015-07-06 | 203.75d | start no earlier than 2015-07-06 |  |  |  |  |  |  |
| 17 | 2.7 | Weekly Review Meeting 7 |  | 2h | 2015-07-13 | 2015-07-13 |  |  |  | 2015-07-13 | 2015-07-13 | 2h | 2015-07-13 | 2015-07-13 | 198.75d | start no earlier than 2015-07-13 |  |  |  |  |  |  |
| 18 | 2.8 | Weekly Review Meeting 8 |  | 2h | 2015-07-20 | 2015-07-20 |  |  |  | 2015-07-20 | 2015-07-20 | 2h | 2015-07-20 | 2015-07-20 | 193.75d | start no earlier than 2015-07-20 |  |  |  |  |  |  |
| 19 | 2.9 | Weekly Review Meeting 9 |  | 2h | 2015-07-27 | 2015-07-27 |  |  |  | 2015-07-27 | 2015-07-27 | 2h | 2015-07-27 | 2015-07-27 | 188.75d | start no earlier than 2015-07-27 |  |  |  |  |  |  |
| 20 | 2.10 | Weekly Review Meeting 10 |  | 2h | 2015-08-03 | 2015-08-03 |  |  |  | 2015-08-03 | 2015-08-03 | 2h | 2015-08-03 | 2015-08-03 | 183.75d | start no earlier than 2015-08-03 |  |  |  |  |  |  |
| 21 | 2.11 | Weekly Review Meeting 11 |  | 2h | 2015-08-10 | 2015-08-10 |  |  |  | 2015-08-10 | 2015-08-10 | 2h | 2015-08-10 | 2015-08-10 | 178.75d | start no earlier than 2015-08-10 |  |  |  |  |  |  |
| 22 | 2.12 | Weekly Review Meeting 12 |  | 2h | 2015-08-17 | 2015-08-17 |  |  |  | 2015-08-17 | 2015-08-17 | 2h | 2015-08-17 | 2015-08-17 | 173.75d | start no earlier than 2015-08-17 |  |  |  |  |  |  |
| 23 | 2.13 | Weekly Review Meeting 13 |  | 2h | 2015-08-24 | 2015-08-24 |  |  |  | 2015-08-24 | 2015-08-24 | 2h | 2015-08-24 | 2015-08-24 | 168.75d | start no earlier than 2015-08-24 |  |  |  |  |  |  |
| 24 | 2.14 | Weekly Review Meeting 14 |  | 2h | 2015-08-31 | 2015-08-31 |  |  |  | 2015-08-31 | 2015-08-31 | 2h | 2015-08-31 | 2015-08-31 | 163.75d | start no earlier than 2015-08-31 |  |  |  |  |  |  |
| 25 | 2.15 | Weekly Review Meeting 15 |  | 2h | 2015-09-08 | 2015-09-08 |  |  |  | 2015-09-08 | 2015-09-08 | 2h | 2015-09-08 | 2015-09-08 | 158.75d | start no earlier than 2015-09-07 |  |  |  |  |  |  |
| 26 | 2.16 | Weekly Review Meeting 16 |  | 2h | 2015-09-14 | 2015-09-14 |  |  |  | 2015-09-14 | 2015-09-14 | 2h | 2015-09-14 | 2015-09-14 | 154.75d | start no earlier than 2015-09-14 |  |  |  |  |  |  |
| 27 | 2.17 | Weekly Review Meeting 17 |  | 2h | 2015-09-21 | 2015-09-21 |  |  |  | 2015-09-21 | 2015-09-21 | 2h | 2015-09-21 | 2015-09-21 | 149.75d | start no earlier than 2015-09-21 |  |  |  |  |  |  |
| 28 | 2.18 | Weekly Review Meeting 18 |  | 2h | 2015-09-28 | 2015-09-28 |  |  |  | 2015-09-28 | 2015-09-28 | 2h | 2015-09-28 | 2015-09-28 | 144.75d | start no earlier than 2015-09-28 |  |  |  |  |  |  |
| 29 | 2.19 | Weekly Review Meeting 19 |  | 2h | 2015-10-05 | 2015-10-05 |  |  |  | 2015-10-05 | 2015-10-05 | 2h | 2015-10-05 | 2015-10-05 | 139.75d | start no earlier than 2015-10-05 |  |  |  |  |  |  |
| 30 | 2.20 | Weekly Review Meeting 20 |  | 2h | 2015-10-13 | 2015-10-13 |  |  |  | 2015-10-13 | 2015-10-13 | 2h | 2015-10-13 | 2015-10-13 | 134.75d | start no earlier than 2015-10-12 |  |  |  |  |  |  |
| 31 | 2.21 | Weekly Review Meeting 21 |  | 2h | 2015-10-19 | 2015-10-19 |  |  |  | 2015-10-19 | 2015-10-19 | 2h | 2015-10-19 | 2015-10-19 | 130.75d | start no earlier than 2015-10-19 |  |  |  |  |  |  |
| 32 | 2.22 | Weekly Review Meeting 22 |  | 2h | 2015-10-26 | 2015-10-26 |  |  |  | 2015-10-26 | 2015-10-26 | 2h | 2015-10-26 | 2015-10-26 | 125.75d | start no earlier than 2015-10-26 |  |  |  |  |  |  |
| 33 | 2.23 | Weekly Review Meeting 23 |  | 2h | 2015-11-02 | 2015-11-02 |  |  |  | 2015-11-02 | 2015-11-02 | 2h | 2015-11-02 | 2015-11-02 | 120.75d | start no earlier than 2015-11-02 |  |  |  |  |  |  |
| 34 | 2.24 | Weekly Review Meeting 24 |  | 2h | 2015-11-09 | 2015-11-09 |  |  |  | 2015-11-09 | 2015-11-09 | 2h | 2015-11-09 | 2015-11-09 | 115.75d | start no earlier than 2015-11-09 |  |  |  |  |  |  |
| 35 | 2.25 | Weekly Review Meeting 25 |  | 2h | 2015-11-16 | 2015-11-16 |  |  |  | 2015-11-16 | 2015-11-16 | 2h | 2015-11-16 | 2015-11-16 | 111.75d | start no earlier than 2015-11-16 |  |  |  |  |  |  |
| 36 | 2.26 | Weekly Review Meeting 26 |  | 2h | 2015-11-23 | 2015-11-23 |  |  |  | 2015-11-23 | 2015-11-23 | 2h | 2015-11-23 | 2015-11-23 | 106.75d | start no earlier than 2015-11-23 |  |  |  |  |  |  |
| 37 | 2.27 | Weekly Review Meeting 27 |  | 2h | 2015-11-30 | 2015-11-30 |  |  |  | 2015-11-30 | 2015-11-30 | 2h | 2015-11-30 | 2015-11-30 | 103.75d | start no earlier than 2015-11-30 |  |  |  |  |  |  |
| 38 | 2.28 | Weekly Review Meeting 28 |  | 2h | 2015-12-07 | 2015-12-07 |  |  |  | 2015-12-07 | 2015-12-07 | 2h | 2015-12-07 | 2015-12-07 | 98.75d | start no earlier than 2015-12-07 |  |  |  |  |  |  |
| 39 | 2.29 | Weekly Review Meeting 29 |  | 2h | 2015-12-14 | 2015-12-14 |  |  |  | 2015-12-14 | 2015-12-14 | 2h | 2015-12-14 | 2015-12-14 | 93.75d | start no earlier than 2015-12-14 |  |  |  |  |  |  |
| 40 | 2.30 | Weekly Review Meeting 30 |  | 2h | 2015-12-21 | 2015-12-21 |  |  |  | 2015-12-21 | 2015-12-21 | 2h | 2015-12-21 | 2015-12-21 | 88.75d | start no earlier than 2015-12-21 |  |  |  |  |  |  |
| 41 | 2.31 | Weekly Review Meeting 31 |  | 2h | 2015-12-28 | 2015-12-28 |  |  |  | 2015-12-28 | 2015-12-28 | 2h | 2015-12-28 | 2015-12-28 | 84.75d | start no earlier than 2015-12-28 |  |  |  |  |  |  |
| 42 | 2.32 | Weekly Review Meeting 32 |  | 2h | 2016-01-04 | 2016-01-04 |  |  |  | 2016-01-04 | 2016-01-04 | 2h | 2016-01-04 | 2016-01-04 | 80.75d | start no earlier than 2016-01-04 |  |  |  |  |  |  |
| 43 | 2.33 | Weekly Review Meeting 33 |  | 2h | 2016-01-11 | 2016-01-11 |  |  |  | 2016-01-11 | 2016-01-11 | 2h | 2016-01-11 | 2016-01-11 | 75.75d | start no earlier than 2016-01-11 |  |  |  |  |  |  |
| 44 | 2.34 | Weekly Review Meeting 34 |  | 2h | 2016-01-19 | 2016-01-19 |  |  |  | 2016-01-19 | 2016-01-19 | 2h | 2016-01-19 | 2016-01-19 | 70.75d | start no earlier than 2016-01-18 |  |  |  |  |  |  |
| 45 | 2.35 | Weekly Review Meeting 35 |  | 2h | 2016-01-25 | 2016-01-25 |  |  |  | 2016-01-25 | 2016-01-25 | 2h | 2016-01-25 | 2016-01-25 | 66.75d | start no earlier than 2016-01-25 |  |  |  |  |  |  |
| 46 | 2.36 | Weekly Review Meeting 36 |  | 2h | 2016-02-01 | 2016-02-01 |  |  |  | 2016-02-01 | 2016-02-01 | 2h | 2016-02-01 | 2016-02-01 | 61.75d | start no earlier than 2016-02-01 |  |  |  |  |  |  |
| 47 | 2.37 | Weekly Review Meeting 37 |  | 2h | 2016-02-08 | 2016-02-08 |  |  |  | 2016-02-08 | 2016-02-08 | 2h | 2016-02-08 | 2016-02-08 | 56.75d | start no earlier than 2016-02-08 |  |  |  |  |  |  |
| 48 | 2.38 | Weekly Review Meeting 38 |  | 2h | 2016-02-16 | 2016-02-16 |  |  |  | 2016-02-16 | 2016-02-16 | 2h | 2016-02-16 | 2016-02-16 | 51.75d | start no earlier than 2016-02-15 |  |  |  |  |  |  |
| 49 | 2.39 | Weekly Review Meeting 39 |  | 2h | 2016-02-22 | 2016-02-22 |  |  |  | 2016-02-22 | 2016-02-22 | 2h | 2016-02-22 | 2016-02-22 | 47.75d | start no earlier than 2016-02-22 |  |  |  |  |  |  |
| 50 | 2.40 | Weekly Review Meeting 40 |  | 2h | 2016-02-29 | 2016-02-29 |  |  |  | 2016-02-29 | 2016-02-29 | 2h | 2016-02-29 | 2016-02-29 | 42.75d | start no earlier than 2016-02-29 |  |  |  |  |  |  |

| ID | WBS | Task | Type | Duration | Start | Finish | Predecessors | Complete | Remaining | Baseline start | Baseline finish | Baseline duration | Baseline 1 start | Baseline 1 finish | Total slack | Free slack | Resources | Work | Actual work | Cost | Baseline cost | Actual cost |
| --- | --- | --- | --- | --- | --- | --- | --- | --- | --- | --- | --- | --- | --- | --- | --- | --- | --- | --- | --- | --- | --- | --- |
| 51 | 3 | **Detailed Design Phase** |  | 74d | 2015-05-26 A | 2015-09-08 |  | 91% | 6.82d | 2015-05-25 | 2015-09-02 | 71d | 2015-05-26 | 2015-09-04 | 158d |  |  | 880h | 776h | 68,640 | 64,760 | 61,720 |
| 52 | 3.1 | Technology Considerations |  | 3d | 2015-05-26 A | 2015-05-28 A | 9 | 100% |  | 2015-05-25 | 2015-05-27 | 3d | 2015-05-26 | 2015-05-28 |  |  | IT Manager | 24h | 24h | 2,040 | 2,040 | 2,040 |
| 53 | 3.2 | Integration Considerations |  | 6d | 2015-05-29 A | 2015-06-05 A | 52 | 100% |  | 2015-05-28 | 2015-06-04 | 6d | 2015-05-29 | 2015-06-05 |  |  | IT Manager | 48h | 48h | 4,080 | 4,080 | 4,080 |
| 54 | 3.3 | Non Functional Requirements |  | 6d | 2015-06-08 A | 2015-06-15 A | 53 | 100% |  | 2015-06-05 | 2015-06-12 | 6d | 2015-06-08 | 2015-06-15 |  |  | IT Director | 48h | 48h | 5,760 | 5,760 | 5,760 |
| 55 | 3.4 | Administrative Needs and Roles |  | 7d | 2015-06-16 A | 2015-06-24 | 54 | 86% | 1d | 2015-06-15 | 2015-06-18 | 4d | 2015-06-16 | 2015-06-24 | 210d |  | IT Manager | 56h | 48h | 4,760 | 2,720 | 4,080 |
| 56 | 3.5 | RACI Matrix for LMS - Org wide |  | 4d | 2015-06-25 A | 2015-06-30 A | 55 | 100% |  | 2015-06-19 | 2015-06-26 | 6d | 2015-06-25 | 2015-06-30 |  |  | PMO | 32h | 32h | 2,720 | 4,080 | 2,720 |
| 57 | 3.6 | Content Strategy |  | 2.4w | 2015-07-01 A | 2015-07-16 A | 56 | 100% |  | 2015-06-29 | 2015-07-10 | 2w | 2015-07-01 | 2015-07-14 |  |  | IT Manager; Faculty Rep; Dean | 288h | 288h | 19,200 | 16,000 | 19,200 |
| 58 | 3.7 | Marketing Requirements |  | 1w | 2015-07-17 A | 2015-07-23 A | 57 | 100% |  | 2015-07-13 | 2015-07-17 | 1w | 2015-07-15 | 2015-07-21 |  |  | PMO | 40h | 40h | 3,400 | 3,400 | 3,400 |
| 59 | 3.8 | Deployment Plan (rollout to all colleges) |  | 1w | 2015-07-24 A | 2015-07-30 A | 58 | 100% |  | 2015-07-20 | 2015-07-24 | 1w | 2015-07-22 | 2015-07-28 |  |  | IT Manager | 40h | 40h | 3,400 | 3,400 | 3,400 |
| 60 | 3.9 | Doc: Functional Specification Document (FSD) |  | 1w | 2015-07-31 A | 2015-08-06 A | 59 | 100% |  | 2015-07-27 | 2015-07-31 | 1w | 2015-07-29 | 2015-08-04 |  |  | Technical Writer | 40h | 40h | 1,800 | 1,800 | 1,800 |
| 61 | 3.10 | Review: FSD |  | 2d | 2015-08-07 A | 2015-08-10 A | 60 | 100% |  | 2015-08-03 | 2015-08-04 | 2d | 2015-08-05 | 2015-08-06 |  |  | IT Director | 16h | 16h | 1,920 | 1,920 | 1,920 |
| 62 | 3.11 | Signoff: FSD |  | 2d | 2015-08-11 A | 2015-08-12 A | 61 | 100% |  | 2015-08-05 | 2015-08-06 | 2d | 2015-08-07 | 2015-08-10 |  |  | IT Director | 16h | 16h | 1,920 | 1,920 | 1,920 |
| 63 | 3.12 | Doc: Technical Specifications Document (TSD) |  | 5d | 2015-08-13 A | 2015-08-19 A | 62 | 100% |  | 2015-08-07 | 2015-08-13 | 5d | 2015-08-11 | 2015-08-17 |  |  | IT Manager | 40h | 40h | 3,400 | 3,400 | 3,400 |
| 64 | 3.13 | Review: TSD |  | 2d | 2015-08-20 A | 2015-08-21 A | 63 | 100% |  | 2015-08-14 | 2015-08-17 | 2d | 2015-08-18 | 2015-08-19 |  |  | IT Director | 16h | 16h | 1,920 | 1,920 | 1,920 |
| 65 | 3.14 | Signoff: TSD |  | 2d | 2015-08-24 A | 2015-08-25 A | 64 | 100% |  | 2015-08-18 | 2015-08-19 | 2d | 2015-08-20 | 2015-08-21 |  |  | IT Director | 16h | 16h | 1,920 | 1,920 | 1,920 |
| 66 | 3.15 | Content Strategy Document (CSD) |  | 2w | 2015-08-26 A | 2015-09-08 | 65 | 40% | 1.2w | 2015-08-20 | 2015-09-02 | 2w | 2015-08-24 | 2015-09-04 | 0d |  | Faculty Rep; IT Manager | 160h | 64h | 10,400 | 10,400 | 4,160 |
| 67 | 3.16 | Milestone: Detailed Design Complete | milestone | 0d | 2015-09-08 | 2015-09-08 | 66 |  |  | 2015-09-02 | 2015-09-02 |  | 2015-09-04 | 2015-09-04 | 0d |  |  |  |  |  |  |  |
| 68 | 4 | **Implementation Phase** |  | 84d | 2015-09-09 | 2016-01-12 |  |  |  | 2015-09-03 | 2016-01-06 | 83d | 2015-09-07 | 2016-01-08 | 0d |  |  | 2320h |  | 225,760 | 225,760 |  |
| 69 | 4.1 | Testing Server Setup |  | 2d | 2015-09-09 | 2015-09-10 | 67 |  |  | 2015-09-03 | 2015-09-04 | 2d | 2015-09-07 | 2015-09-08 | 89d | 0d | Deploy Team | 16h |  | 1,280 | 1,280 |  |
| 70 | 4.2 | Development Server Setup |  | 2d | 2015-09-11 | 2015-09-14 | 69 |  |  | 2015-09-07 | 2015-09-08 | 2d | 2015-09-09 | 2015-09-10 | 89d | 0d | Deploy Team | 16h |  | 1,280 | 1,280 |  |
| 71 | 4.3 | Install: Moodle Test installation |  | 1d | 2015-09-15 | 2015-09-15 | 70 |  |  | 2015-09-09 | 2015-09-09 | 1d | 2015-09-11 | 2015-09-11 | 89d | 0d | Deploy Team | 8h |  | 640 | 640 |  |
| 72 | 4.4 | Database design |  | 5d | 2015-09-16 | 2015-09-22 | 71 |  |  | 2015-09-10 | 2015-09-16 | 5d | 2015-09-14 | 2015-09-18 | 89d | 0d | Architect | 40h |  | 3,600 | 3,600 |  |
| 73 | 4.5 | Doc: Upgrade Strategy Document (USD) |  | 5d | 2015-09-23 | 2015-09-29 | 72 |  |  | 2015-09-17 | 2015-09-23 | 5d | 2015-09-21 | 2015-09-25 | 89d | 0d | Architect | 40h |  | 3,600 | 3,600 |  |
| 74 | 4.6 | **Moodle: LMS Structure** |  | 19d | 2015-09-30 | 2015-10-27 |  |  |  | 2015-09-24 | 2015-10-21 | 19d | 2015-09-28 | 2015-10-23 | 89d |  |  | 160h |  | 11,200 | 11,200 |  |
| 75 | 4.6.1 | Home Page |  | 3d | 2015-09-30 | 2015-10-02 | 73 |  |  | 2015-09-24 | 2015-09-28 | 3d | 2015-09-28 | 2015-09-30 | 88d | 0d | Develop Team | 24h |  | 1,680 | 1,680 |  |
| 76 | 4.6.2 | Main Landing Page |  | 8d | 2015-10-05 | 2015-10-14 | 75 |  |  | 2015-09-29 | 2015-10-08 | 8d | 2015-10-01 | 2015-10-12 | 88d | 0d | Develop Team | 64h |  | 4,480 | 4,480 |  |
| 77 | 4.6.3 | Institution Landing Pages |  | 5d | 2015-10-15 | 2015-10-21 | 76 |  |  | 2015-10-09 | 2015-10-15 | 5d | 2015-10-13 | 2015-10-19 | 89d | 0d | Develop Team | 40h |  | 2,800 | 2,800 |  |
| 78 | 4.6.4 | Course Landing Pages |  | 4d | 2015-10-22 | 2015-10-27 | 77 |  |  | 2015-10-16 | 2015-10-21 | 4d | 2015-10-20 | 2015-10-23 | 89d | 0d | Develop Team | 32h |  | 2,240 | 2,240 |  |

| ID | WBS | Task | Type | Duration | Start | Finish | Predecessors | Baseline start | Baseline finish | Baseline duration | Baseline 1 start | Baseline 1 finish | Total slack | Free slack | Resources | Work | Cost | Baseline cost |
| --- | --- | --- | --- | --- | --- | --- | --- | --- | --- | --- | --- | --- | --- | --- | --- | --- | --- | --- |
| 79 | 4.7 | **Moodle: Course Design and Planning** |  | 11d | 2015-10-28 | 2015-11-12 |  | 2015-10-22 | 2015-11-06 | 12d | 2015-10-26 | 2015-11-10 | 89d |  |  | 96h | 4,320 | 4,320 |
| 80 | 4.7.1 | Courses Upload |  | 5d | 2015-10-28 | 2015-11-03 | 78 | 2015-10-22 | 2015-10-28 | 5d | 2015-10-26 | 2015-10-30 | 89d | 0d | Content Team | 40h | 1,800 | 1,800 |
| 81 | 4.7.2 | Courses Structuring |  | 4d | 2015-11-04 | 2015-11-09 | 80 | 2015-10-29 | 2015-11-03 | 4d | 2015-11-02 | 2015-11-05 | 89d | 0d | Content Team | 32h | 1,440 | 1,440 |
| 82 | 4.7.3 | Courses Support Material Upload |  | 3d | 2015-11-10 | 2015-11-12 | 81 | 2015-11-04 | 2015-11-06 | 3d | 2015-11-06 | 2015-11-10 | 89d | 0d | Content Team | 24h | 1,080 | 1,080 |
| 83 | 4.8 | **Moodle: Course Creation** |  | 10d | 2015-11-13 | 2015-11-30 |  | 2015-11-09 | 2015-11-24 | 11d | 2015-11-11 | 2015-11-26 | 90d |  |  | 96h | 4,320 | 4,320 |
| 84 | 4.8.1 | Course Space Creation |  | 5d | 2015-11-13 | 2015-11-19 | 82 | 2015-11-09 | 2015-11-13 | 5d | 2015-11-11 | 2015-11-17 | 90d | 0d | Content Team | 40h | 1,800 | 1,800 |
| 85 | 4.8.2 | Course Pages |  | 4d | 2015-11-20 | 2015-11-25 | 84 | 2015-11-16 | 2015-11-19 | 4d | 2015-11-18 | 2015-11-23 | 90d | 0d | Content Team | 32h | 1,440 | 1,440 |
| 86 | 4.8.3 | Assessment Requirements |  | 3d | 2015-11-26 | 2015-11-30 | 85 | 2015-11-20 | 2015-11-24 | 3d | 2015-11-24 | 2015-11-26 | 90d | 0d | Faculty Rep | 24h | 1,080 | 1,080 |
| 87 | 4.9 | **Moodle: Performance and Control Considerations** |  | 12d | 2015-12-01 | 2015-12-16 |  | 2015-11-25 | 2015-12-10 | 10d | 2015-11-27 | 2015-12-14 | 91d |  |  | 96h | 6,120 | 6,120 |
| 88 | 4.9.1 | Automated and Manual Communications setup |  | 5d | 2015-12-01 | 2015-12-07 | 86 | 2015-11-25 | 2015-12-01 | 5d | 2015-11-27 | 2015-12-03 | 91d | 0d | Architect | 40h | 3,600 | 3,600 |
| 89 | 4.9.2 | Support Pages Configuration |  | 4d | 2015-12-08 | 2015-12-11 | 88 | 2015-12-02 | 2015-12-07 | 4d | 2015-12-04 | 2015-12-09 | 91d | 0d | Faculty Rep | 32h | 1,440 | 1,440 |
| 90 | 4.9.3 | Course Release Strategy |  | 3d | 2015-12-14 | 2015-12-16 | 89 | 2015-12-08 | 2015-12-10 | 3d | 2015-12-10 | 2015-12-14 | 91d |  | Content Team | 24h | 1,080 | 1,080 |
| 91 | 4.10 | **LMS User Experience** |  | 33d | 2015-09-09 | 2015-10-26 |  | 2015-09-03 | 2015-10-20 | 32d | 2015-09-07 | 2015-10-22 | 51d |  |  | 272h | 27,200 | 27,200 |
| 92 | 4.10.1 | Doc: UX Design document (UXD) |  | 5d | 2015-09-09 | 2015-09-15 | 67 | 2015-09-03 | 2015-09-09 | 5d | 2015-09-07 | 2015-09-11 | 52d | 0d | Web Design Vendor | 40h | 4,000 | 4,000 |
| 93 | 4.10.2 | Review: UXD |  | 2d | 2015-09-16 | 2015-09-17 | 92 | 2015-09-10 | 2015-09-11 | 2d | 2015-09-14 | 2015-09-15 | 52d | 0d | Web Design Vendor | 16h | 1,600 | 1,600 |
| 94 | 4.10.3 | Signoff: UXD |  | 2d | 2015-09-18 | 2015-09-21 | 93 | 2015-09-14 | 2015-09-15 | 2d | 2015-09-16 | 2015-09-17 | 52d | 0d | Web Design Vendor | 16h | 1,600 | 1,600 |
| 95 | 4.10.4 | Custom Theme Development |  | 2w | 2015-09-22 | 2015-10-05 | 94 | 2015-09-16 | 2015-09-29 | 2w | 2015-09-18 | 2015-10-01 | 52d | 0d | Web Design Vendor | 80h | 8,000 | 8,000 |
| 96 | 4.10.5 | Department-wide custom themes |  | 1w | 2015-10-06 | 2015-10-12 | 95 | 2015-09-30 | 2015-10-06 | 1w | 2015-10-02 | 2015-10-08 | 52d | 0d | Web Design Vendor | 40h | 4,000 | 4,000 |
| 97 | 4.10.6 | Logo and Branding requirements |  | 5d | 2015-10-13 | 2015-10-19 | 96 | 2015-10-07 | 2015-10-13 | 5d | 2015-10-09 | 2015-10-15 | 51d | 0d | Web Design Vendor | 40h | 4,000 | 4,000 |
| 98 | 4.10.7 | Marketing UX reqts |  | 5d | 2015-10-20 | 2015-10-26 | 97 | 2015-10-14 | 2015-10-20 | 5d | 2015-10-16 | 2015-10-22 | 51d | 0d | Web Design Vendor | 40h | 4,000 | 4,000 |
| 99 | 4.10.8 | Milestone: UX complete | milestone | 0d | 2015-10-26 | 2015-10-26 | 98 | 2015-10-20 | 2015-10-20 |  | 2015-10-22 | 2015-10-22 | 51d |  | Web Design Vendor |  |  |  |
| 100 | 4.11 | **LMS Content Migration** |  | 84d | 2015-09-09 | 2016-01-12 |  | 2015-09-03 | 2016-01-06 | 83d | 2015-09-07 | 2016-01-08 | 0d |  |  | 720h | 84,000 | 84,000 |
| 101 | 4.11.1 | Content Vendor Selection |  | 5d | 2015-09-09 | 2015-09-15 | 67 | 2015-09-03 | 2015-09-09 | 5d | 2015-09-07 | 2015-09-11 | 0d |  | PM | 40h | 3,600 | 3,600 |
| 102 | 4.11.2 | Content Vendor Engage |  | 5d | 2015-09-16 | 2015-09-22 | 101 | 2015-09-10 | 2015-09-16 | 5d | 2015-09-14 | 2015-09-18 | 0d |  | PM | 40h | 3,600 | 3,600 |
| 103 | 4.11.3 | Migrate SCORM Content |  | 10d | 2015-09-23 | 2015-10-06 | 102 | 2015-09-17 | 2015-09-30 | 10d | 2015-09-21 | 2015-10-02 | 0d |  | Content Vendor | 80h | 9,600 | 9,600 |
| 104 | 4.11.4 | Vendonr: New Content Creation |  | 60d | 2015-10-07 | 2015-12-29 | 103 | 2015-10-01 | 2015-12-23 | 60d | 2015-10-05 | 2015-12-25 | 0d |  | Content Vendor | 480h | 57,600 | 57,600 |
| 105 | 4.11.5 | Vendor: New content Upload |  | 10d | 2015-12-30 | 2016-01-12 | 104 | 2015-12-24 | 2016-01-06 | 10d | 2015-12-28 | 2016-01-08 | 0d |  | Content Vendor | 80h | 9,600 | 9,600 |
| 106 | 4.11.6 | Milestone: Migration done | milestone | 0d | 2016-01-12 | 2016-01-12 | 105 | 2016-01-06 | 2016-01-06 |  | 2016-01-08 | 2016-01-08 | 0d |  | Content Vendor |  |  |  |

| ID | WBS | Task | Type | Duration | Start | Finish | Predecessors | Baseline start | Baseline finish | Baseline duration | Baseline 1 start | Baseline 1 finish | Total slack | Free slack | Resources | Work | Cost | Baseline cost |
| --- | --- | --- | --- | --- | --- | --- | --- | --- | --- | --- | --- | --- | --- | --- | --- | --- | --- | --- |
| 107 | 4.12 | **Mobile App Development** |  | 56d | 2015-09-30 | 2015-12-22 |  | 2015-09-25 | 2015-12-17 | 56d | 2015-09-29 | 2015-12-21 | 13d |  |  | 480h | 58,600 | 58,600 |
| 108 | 4.12.1 | Mobile Dev Vendor Selection |  | 1w | 2015-09-30 | 2015-10-06 | 67FS+15d | 2015-09-25 | 2015-10-01 | 1w | 2015-09-29 | 2015-10-05 | 14d | 0d | PM | 40h | 3,600 | 3,600 |
| 109 | 4.12.2 | Requirements and signoff |  | 2w | 2015-10-07 | 2015-10-20 | 108 | 2015-10-02 | 2015-10-15 | 2w | 2015-10-06 | 2015-10-19 | 14d | 0d | Mobile Vendor | 80h | 10,000 | 10,000 |
| 110 | 4.12.3 | Notifications |  | 4d | 2015-10-21 | 2015-10-26 | 109 | 2015-10-16 | 2015-10-21 | 4d | 2015-10-20 | 2015-10-23 | 14d | 0d | Mobile Vendor | 32h | 4,000 | 4,000 |
| 111 | 4.12.4 | Calendar |  | 2d | 2015-10-27 | 2015-10-28 | 110 | 2015-10-22 | 2015-10-23 | 2d | 2015-10-26 | 2015-10-27 | 14d | 0d | Mobile Vendor | 16h | 2,000 | 2,000 |
| 112 | 4.12.5 | Quiz Engine |  | 15d | 2015-10-29 | 2015-11-18 | 111 | 2015-10-26 | 2015-11-13 | 15d | 2015-10-28 | 2015-11-17 | 13d | 0d | Mobile Vendor | 120h | 15,000 | 15,000 |
| 113 | 4.12.6 | Annual Time Table |  | 2d | 2015-11-19 | 2015-11-20 | 112 | 2015-11-16 | 2015-11-17 | 2d | 2015-11-18 | 2015-11-19 | 13d | 0d | Mobile Vendor | 16h | 2,000 | 2,000 |
| 114 | 4.12.7 | Messaging |  | 1w | 2015-11-23 | 2015-11-27 | 113 | 2015-11-18 | 2015-11-24 | 1w | 2015-11-20 | 2015-11-26 | 13d | 0d | Mobile Vendor | 40h | 5,000 | 5,000 |
| 115 | 4.12.8 | Social Integration |  | 2d | 2015-11-30 | 2015-12-01 | 114 | 2015-11-25 | 2015-11-26 | 2d | 2015-11-27 | 2015-11-30 | 15d | 0d | Mobile Vendor | 16h | 2,000 | 2,000 |
| 116 | 4.12.9 | Usability Testing |  | 5d | 2015-12-02 | 2015-12-08 | 115 | 2015-11-27 | 2015-12-03 | 5d | 2015-12-01 | 2015-12-07 | 14d | 0d | Mobile Vendor | 40h | 5,000 | 5,000 |
| 117 | 4.12.10 | Functional Testing |  | 5d | 2015-12-09 | 2015-12-15 | 116 | 2015-12-04 | 2015-12-10 | 5d | 2015-12-08 | 2015-12-14 | 13d | 0d | Mobile Vendor | 40h | 5,000 | 5,000 |
| 118 | 4.12.11 | Integration testing |  | 5d | 2015-12-16 | 2015-12-22 | 117 | 2015-12-11 | 2015-12-17 | 5d | 2015-12-15 | 2015-12-21 | 13d | 0d | Mobile Vendor | 40h | 5,000 | 5,000 |
| 119 | 4.12.12 | Milestone: Mobile dev complete | milestone | 0d | 2015-12-22 | 2015-12-22 | 118 | 2015-12-17 | 2015-12-17 |  | 2015-12-21 | 2015-12-21 | 13d |  | Mobile Vendor |  |  |  |
| 120 | 4.13 | **Testing Plan and Setup** |  | 32d | 2015-10-22 | 2015-12-09 |  | 2015-10-19 | 2015-12-04 | 32d | 2015-10-21 | 2015-12-08 | 22d |  |  | 280h | 19,600 | 19,600 |
| 121 | 4.13.1 | Doc: Test Specification Document (TSD) |  | 2w | 2015-10-22 | 2015-11-04 | 67FS+30d | 2015-10-19 | 2015-10-30 | 2w | 2015-10-21 | 2015-11-03 | 21d | 0d | Test Lead | 80h | 5,600 | 5,600 |
| 122 | 4.13.2 | Test team setup |  | 5d | 2015-11-05 | 2015-11-11 | 121 | 2015-11-02 | 2015-11-06 | 5d | 2015-11-04 | 2015-11-10 | 21d | 0d | Test Lead | 40h | 2,800 | 2,800 |
| 123 | 4.13.3 | Review: TSD |  | 3d | 2015-11-12 | 2015-11-16 | 122 | 2015-11-09 | 2015-11-11 | 3d | 2015-11-11 | 2015-11-13 | 22d | 0d | Test Lead | 24h | 1,680 | 1,680 |
| 124 | 4.13.4 | Signoff: TSD |  | 2d | 2015-11-17 | 2015-11-18 | 123 | 2015-11-12 | 2015-11-13 | 2d | 2015-11-16 | 2015-11-17 | 22d | 0d | Test Lead | 16h | 1,120 | 1,120 |
| 125 | 4.13.5 | Content Test Strategy |  | 2w | 2015-11-19 | 2015-12-02 | 124 | 2015-11-16 | 2015-11-27 | 2w | 2015-11-18 | 2015-12-01 | 22d | 0d | Test Lead | 80h | 5,600 | 5,600 |
| 126 | 4.13.6 | Usability Test Strategy |  | 1w | 2015-12-03 | 2015-12-09 | 125 | 2015-11-30 | 2015-12-04 | 1w | 2015-12-02 | 2015-12-08 | 22d |  | Test Lead | 40h | 2,800 | 2,800 |
| 127 | 4.14 | Milestone: Implementation Complete | milestone | 0d | 2016-01-12 | 2016-01-12 | 126, 106, 119, 99 | 2016-01-06 | 2016-01-06 |  | 2016-01-08 | 2016-01-08 | 0d |  |  |  |  |  |
| 128 | 5 | **Integration Phase** |  | 52d | 2016-01-13 | 2016-03-28 |  | 2016-01-07 | 2016-03-22 | 52d | 2016-01-11 | 2016-03-24 | 0d |  |  | 432h | 34,560 | 34,560 |
| 129 | 5.1 | Single Sign On (SSO) Setup |  | 3d | 2016-01-13 | 2016-01-15 | 127 | 2016-01-07 | 2016-01-11 | 3d | 2016-01-11 | 2016-01-13 | 0d |  | Deploy Team | 24h | 1,920 | 1,920 |
| 130 | 5.2 | Student Information System (SIS) Setup |  | 5d | 2016-01-18 | 2016-01-22 | 129 | 2016-01-12 | 2016-01-18 | 5d | 2016-01-14 | 2016-01-20 | 1d | 0d | Deploy Team | 40h | 3,200 | 3,200 |
| 131 | 5.3 | Datewarehousing Integration (Learning Analytics) |  | 10d | 2016-01-25 | 2016-02-05 | 130 | 2016-01-19 | 2016-02-01 | 10d | 2016-01-21 | 2016-02-03 | 2d | 0d | Deploy Team | 80h | 6,400 | 6,400 |
| 132 | 5.4 | SAP Integration |  | 15d | 2016-02-08 | 2016-02-26 | 131 | 2016-02-02 | 2016-02-22 | 15d | 2016-02-04 | 2016-02-24 | 2d | 0d | Deploy Team | 120h | 9,600 | 9,600 |
| 133 | 5.5 | Accounting Software Setup |  | 5d | 2016-02-29 | 2016-03-04 | 132 | 2016-02-23 | 2016-02-29 | 5d | 2016-02-25 | 2016-03-02 | 2d | 0d | Deploy Team | 40h | 3,200 | 3,200 |

Notes:
- 121: Start writing the Test Plan after the detailed design is complete - and implementation has started
- 127: Note the multiple dependencies for this milestone to complete

| ID | WBS | Task | Type | Duration | Start | Finish | Predecessors | Baseline start | Baseline finish | Baseline duration | Baseline 1 start | Baseline 1 finish | Total slack | Free slack | Resources | Work | Cost | Baseline cost |
| --- | --- | --- | --- | --- | --- | --- | --- | --- | --- | --- | --- | --- | --- | --- | --- | --- | --- | --- |
| 134 | 5.6 | **STAGING SERVER SETUP** |  | 16d | 2016-03-07 | 2016-03-28 |  | 2016-03-01 | 2016-03-22 | 16d | 2016-03-03 | 2016-03-24 | 2d |  |  | 128h | 10,240 | 10,240 |
| 135 | 5.6.1 | Server setup, Redundancy setup |  | 3d | 2016-03-07 | 2016-03-09 | 133 | 2016-03-01 | 2016-03-03 | 3d | 2016-03-03 | 2016-03-07 | 2d | 0d | Deploy Team | 24h | 1,920 | 1,920 |
| 136 | 5.6.2 | Database Configuration |  | 3d | 2016-03-10 | 2016-03-14 | 135 | 2016-03-04 | 2016-03-08 | 3d | 2016-03-08 | 2016-03-10 | 2d | 0d | Deploy Team | 24h | 1,920 | 1,920 |
| 137 | 5.6.3 | LMS Installation |  | 2d | 2016-03-15 | 2016-03-16 | 136 | 2016-03-09 | 2016-03-10 | 2d | 2016-03-11 | 2016-03-14 | 2d | 0d | Deploy Team | 16h | 1,280 | 1,280 |
| 138 | 5.6.4 | Course Data Migration |  | 3d | 2016-03-17 | 2016-03-21 | 137 | 2016-03-11 | 2016-03-15 | 3d | 2016-03-15 | 2016-03-17 | 2d | 0d | Deploy Team | 24h | 1,920 | 1,920 |
| 139 | 5.6.5 | Student Data Import |  | 3d | 2016-03-22 | 2016-03-24 | 138 | 2016-03-16 | 2016-03-18 | 3d | 2016-03-18 | 2016-03-22 | 2d | 0d | Deploy Team | 24h | 1,920 | 1,920 |
| 140 | 5.6.6 | RBAC Setup and testing |  | 2d | 2016-03-25 | 2016-03-28 | 139 | 2016-03-21 | 2016-03-22 | 2d | 2016-03-23 | 2016-03-24 | 2d | 0d | Deploy Team | 16h | 1,280 | 1,280 |
| 141 | 5.6.7 | Milestone: Integration Phase Complete | milestone | 0d | 2016-03-28 | 2016-03-28 | 140 | 2016-03-22 | 2016-03-22 |  | 2016-03-24 | 2016-03-24 | 2d | 0d |  |  |  |  |
| 142 | 6 | **VERIFICATION and STAGING** |  | 117d | 2015-10-28 | 2016-04-19 |  | 2015-10-22 | 2016-04-13 | 118d | 2015-10-26 | 2016-04-15 | 7d |  |  | 1080h | 56,600 | 56,600 |
| 143 | 6.1 | Unit Testing of all modules |  | 2mo | 2015-10-28 | 2015-12-22 | 68SS+2.5% | 2015-10-22 | 2015-12-16 | 2mo | 2015-10-26 | 2015-12-18 | 6d | 0d | Develop Team | 320h | 22,400 | 22,400 |
| 144 | 6.2 | Functional Testing |  | 3w | 2015-12-23 | 2016-01-12 | 143 | 2015-12-17 | 2016-01-06 | 3w | 2015-12-21 | 2016-01-08 | 6d | 0d | Testing Team | 120h | 5,400 | 5,400 |
| 145 | 6.3 | Installation and Deploy Testing |  | 2w | 2016-01-13 | 2016-01-26 | 144 | 2016-01-07 | 2016-01-20 | 2w | 2016-01-11 | 2016-01-22 | 6d | 0d | Testing Team | 80h | 3,600 | 3,600 |
| 146 | 6.4 | Performance Testing |  | 2w | 2016-01-27 | 2016-02-09 | 145 | 2016-01-21 | 2016-02-03 | 2w | 2016-01-25 | 2016-02-05 | 6d | 0d | Testing Team | 80h | 3,600 | 3,600 |
| 147 | 6.5 | Usability Testing |  | 2w | 2016-02-10 | 2016-02-23 | 146 | 2016-02-04 | 2016-02-17 | 2w | 2016-02-08 | 2016-02-19 | 6d | 0d | Testing Team | 80h | 3,600 | 3,600 |
| 148 | 6.6 | Alpha Testing |  | 2w | 2016-02-24 | 2016-03-08 | 147 | 2016-02-18 | 2016-03-02 | 2w | 2016-02-22 | 2016-03-04 | 7d | 0d | Testing Team | 80h | 3,600 | 3,600 |
| 149 | 6.7 | UAT Scripting |  | 2w | 2016-03-09 | 2016-03-22 | 148 | 2016-03-03 | 2016-03-16 | 2w | 2016-03-07 | 2016-03-18 | 7d | 0d | Testing Team | 80h | 3,600 | 3,600 |
| 150 | 6.8 | UAT cases review and approval |  | 2w | 2016-03-23 | 2016-04-05 | 149 | 2016-03-17 | 2016-03-30 | 2w | 2016-03-21 | 2016-04-01 | 7d | 0d | Testing Team | 80h | 3,600 | 3,600 |
| 151 | 6.9 | User Acceptance Testing |  | 2w | 2016-04-06 | 2016-04-19 | 150 | 2016-03-31 | 2016-04-13 | 2w | 2016-04-04 | 2016-04-15 | 7d | 0d | Testing Team; Faculty Rep | 160h | 7,200 | 7,200 |
| 152 | 6.10 | Milestone: Testing Complete | milestone | 0d | 2016-04-19 | 2016-04-19 | 151 | 2016-04-13 | 2016-04-13 |  | 2016-04-15 | 2016-04-15 | 7d |  |  |  |  |  |
| 153 | 7 | **PRODUCTION DEPLOYMENT** |  | 20d | 2016-03-29 | 2016-04-26 |  | 2016-03-23 | 2016-04-20 | 20d | 2016-03-25 | 2016-04-22 | 2d |  |  | 168h | 13,440 | 13,440 |
| 154 | 7.1 | Hardware, Software, Database Setup, Configuration |  | 5d | 2016-03-29 | 2016-04-04 | 141 | 2016-03-23 | 2016-03-29 | 5d | 2016-03-25 | 2016-03-31 | 2d | 0d | Deploy Team | 40h | 3,200 | 3,200 |
| 155 | 7.2 | Course Data Migration |  | 6d | 2016-04-05 | 2016-04-12 | 154 | 2016-03-30 | 2016-04-06 | 6d | 2016-04-01 | 2016-04-08 | 2d | 0d | Deploy Team | 48h | 3,840 | 3,840 |
| 156 | 7.3 | Student Data Migration |  | 4d | 2016-04-13 | 2016-04-18 | 155 | 2016-04-07 | 2016-04-12 | 4d | 2016-04-11 | 2016-04-14 | 2d | 0d | Deploy Team | 32h | 2,560 | 2,560 |
| 157 | 7.4 | Course Creation - all Colleges |  | 5d | 2016-04-19 | 2016-04-25 | 156 | 2016-04-13 | 2016-04-19 | 5d | 2016-04-15 | 2016-04-21 | 2d | 0d | Deploy Team | 40h | 3,200 | 3,200 |
| 158 | 7.5 | Roles and Accounts |  | 1d | 2016-04-26 | 2016-04-26 | 157 | 2016-04-20 | 2016-04-20 | 1d | 2016-04-22 | 2016-04-22 | 2d | 0d | Deploy Team | 8h | 640 | 640 |
| 159 | 7.6 | Milestone: Prod Deploy Complete | milestone | 0d | 2016-04-26 | 2016-04-26 | 158 | 2016-04-20 | 2016-04-20 |  | 2016-04-22 | 2016-04-22 | 2d |  |  |  |  |  |

Notes:
- 144: Testing can start when Implementation has completed atleast 25%

| ID | WBS | Task | Type | Duration | Start | Finish | Predecessors | Baseline start | Baseline finish | Baseline duration | Baseline 1 start | Baseline 1 finish | Total slack | Resources | Work | Cost | Baseline cost |
| --- | --- | --- | --- | --- | --- | --- | --- | --- | --- | --- | --- | --- | --- | --- | --- | --- | --- |
| 160 | 8 | **Maintenance Handover** |  | 54d | 2016-02-11 | 2016-04-28 |  | 2016-02-05 | 2016-04-22 | 54d | 2016-02-09 | 2016-04-26 | 0d |  | 488h | 37,120 | 37,120 |
| 161 | 8.1 | Training Calendar |  | 3d | 2016-02-11 | 2016-02-15 | 129SS+20d | 2016-02-05 | 2016-02-09 | 3d | 2016-02-09 | 2016-02-11 | 0d | PM | 24h | 2,160 | 2,160 |
| 162 | 8.2 | Maintenance Vendor Selection |  | 20d | 2016-02-16 | 2016-03-14 | 161 | 2016-02-10 | 2016-03-08 | 20d | 2016-02-12 | 2016-03-10 | 0d | PM | 160h | 14,400 | 14,400 |
| 163 | 8.3 | Maintenance Vendor Engagement |  | 5d | 2016-03-15 | 2016-03-21 | 162 | 2016-03-09 | 2016-03-15 | 5d | 2016-03-11 | 2016-03-17 | 0d | PM | 40h | 3,600 | 3,600 |
| 164 | 8.4 | User Manual |  | 10d | 2016-03-22 | 2016-04-04 | 163 | 2016-03-16 | 2016-03-29 | 10d | 2016-03-18 | 2016-03-31 | 0d | Technical Writer | 80h | 3,600 | 3,600 |
| 165 | 8.5 | Administration Manual |  | 10d | 2016-04-05 | 2016-04-18 | 164 | 2016-03-30 | 2016-04-12 | 10d | 2016-04-01 | 2016-04-14 | 0d | Technical Writer | 80h | 3,600 | 3,600 |
| 166 | 8.6 | Techno Functional Handover |  | 3d | 2016-04-19 | 2016-04-21 | 165 | 2016-04-13 | 2016-04-15 | 3d | 2016-04-15 | 2016-04-19 | 0d | PM | 24h | 2,160 | 2,160 |
| 167 | 8.7 | Training Org Wide |  | 5d | 2016-04-22 | 2016-04-28 | 166 | 2016-04-18 | 2016-04-22 | 5d | 2016-04-20 | 2016-04-26 | 0d | PM | 40h | 3,600 | 3,600 |
| 168 | 8.8 | **BUGZILLA** |  | 5d | 2016-04-22 | 2016-04-28 |  | 2016-04-18 | 2016-04-22 | 5d | 2016-04-20 | 2016-04-26 | 0d |  | 40h | 4,000 | 4,000 |
| 169 | 8.8.1 | Issue Tracking BUGZILLA installation |  | 2d | 2016-04-22 | 2016-04-25 | 166 | 2016-04-18 | 2016-04-19 | 2d | 2016-04-20 | 2016-04-21 | 0d | Maintenance Vendor | 16h | 1,600 | 1,600 |
| 170 | 8.8.2 | Bugzilla accounts, training and access handover |  | 3d | 2016-04-26 | 2016-04-28 | 169 | 2016-04-20 | 2016-04-22 | 3d | 2016-04-22 | 2016-04-26 | 0d | Maintenance Vendor | 24h | 2,400 | 2,400 |
| 171 | 8.8.3 | Milestone: Project Complete | milestone | 0d | 2016-04-28 | 2016-04-28 | 170 | 2016-04-22 | 2016-04-22 |  | 2016-04-26 | 2016-04-26 | 0d |  |  |  |  |

Notes:
- 167: To be planned in greater detail
